# SP_K21178_CTE_01_PWB relo in ODOT contract & other UT concurrent

Schedule from MS Project, 2021-08-30 to 2027-05-13.
HDR Inc

## Calendars

- Standard: Mon-Fri 08:00-12:00, 13:00-17:00; Sat-Sun off.
- 7 Day per Week: Mon-Sun 08:00-12:00, 13:00-17:00.

## Schedule

| ID | WBS | Task | Type | Duration | Start | Finish | Predecessors | Total slack | Free slack | Constraint | Calendar |
| --- | --- | --- | --- | --- | --- | --- | --- | --- | --- | --- | --- |
| 1 | 1 | Estimated Construction Schedule is Preliminary - Not for Construction | manual | 1d? | 2021-08-30 | 2021-08-30 |  |  |  |  |  |
| 2 | 2 | **US-26 (Powell Boulevard): SE 99th Ave - ECL Sec.** |  | 1357d | 2022-03-02 | 2027-05-13 |  | 0d |  |  |  |
| 3 | 2.1 | **ADVERTISE, BID, AWARD** |  | 77d | 2022-12-08 | 2023-03-24 |  | 183d |  |  |  |
| 4 | 2.1.1 | Advertise |  | 35d | 2022-12-08 | 2023-01-25 |  | 183d | 0d | start no earlier than 2022-12-08 |  |
| 5 | 2.1.2 | Bid Opening |  | 1d | 2023-01-26 | 2023-01-26 | 4 | 183d | 0d |  |  |
| 6 | 2.1.3 | Award of Contract |  | 30d | 2023-01-27 | 2023-02-25 | 5 | 257d | 0d |  | 7 Day per Week |
| 7 | 2.1.4 | Execution of Contract by Bidder |  | 15d | 2023-02-26 | 2023-03-12 | 6 | 257d | 0d |  | 7 Day per Week |
| 8 | 2.1.5 | Execution of Contract by State |  | 7d | 2023-03-13 | 2023-03-19 | 7 | 257d | 0d |  | 7 Day per Week |
| 9 | 2.1.6 | NTP |  | 5d | 2023-03-20 | 2023-03-24 | 8 | 257d | 2d |  | 7 Day per Week |
| 10 | 2.2 | **SUBMITTALS** |  | 140d | 2023-03-27 | 2023-10-06 |  | 183d |  |  |  |
| 11 | 2.2.1 | Traffic Control Plans |  | 10d | 2023-03-27 | 2023-04-07 | 9 | 1069d |  |  |  |
| 12 | 2.2.2 | Construction Staging Plans |  | 10d | 2023-03-27 | 2023-04-07 | 9 | 1069d |  |  |  |
| 13 | 2.2.3 | Contractor Sidewalk Ramp Plan |  | 15d | 2023-03-27 | 2023-04-14 | 9 | 1064d |  |  |  |
| 14 | 2.2.4 | Construction Schedule |  | 10d | 2023-03-27 | 2023-04-07 | 9 | 1069d |  |  |  |
| 15 | 2.2.5 | **Material Submittals** |  | 20d | 2023-03-27 | 2023-04-21 |  | 183d |  |  |  |
| 16 | 2.2.5.1 | Signal and Luminaire Hardware |  | 20d | 2023-03-27 | 2023-04-21 | 9 | 532d | 0d |  |  |
| 17 | 2.2.5.2 | Noise Barrier Panels |  | 20d | 2023-03-27 | 2023-04-21 | 9 | 999d | 0d |  |  |
| 18 | 2.2.5.3 | Ductile Iron Pipe |  | 15d | 2023-03-27 | 2023-04-14 | 9 | 183d | 0d |  |  |
| 19 | 2.2.6 | **Long Lead Items** |  | 125d | 2023-04-17 | 2023-10-06 |  | 183d |  |  |  |
| 20 | 2.2.6.1 | Permanent Signal and Luminaire Supports |  | 120d | 2023-04-24 | 2023-10-06 | 16 | 939d |  |  |  |
| 21 | 2.2.6.2 | Temporary Signal Hardware |  | 80d | 2023-04-24 | 2023-08-11 | 16 | 532d | 0d |  |  |
| 22 | 2.2.6.3 | Noise Barrier Panels |  | 60d | 2023-04-24 | 2023-07-14 | 17 | 999d |  |  |  |
| 23 | 2.2.6.4 | Ductile Iron Pipe |  | 20d | 2023-04-17 | 2023-05-12 | 18 | 183d | 0d |  |  |
| 24 | 2.3 | 2022 Nesting Season (No Tree Cutting) |  | 131d | 2022-03-02 | 2022-08-31 |  | 1226d |  | finish no earlier than 2022-08-31 |  |
| 25 | 2.4 | 2025-2026 Winter Wearing Course Paving Shut Down |  | 118d | 2025-10-01 | 2026-03-13 |  | 304d |  | start no earlier than 2025-10-01 |  |
| 26 | 2.5 | 2026-2027 Winter Wearing Course Paving Shut Down |  | 118d | 2026-10-01 | 2027-03-15 |  | 0d |  | start no earlier than 2026-10-01 |  |
| 27 | 2.6 | 2023-2024 Winter Work Shut Down (In specs) |  | 36d | 2023-11-22 | 2024-01-10 |  | 139d | 0d | start no earlier than 2023-11-22 |  |
| 28 | 2.7 | 2024-2025 Winter Work Shut Down (In specs) |  | 33d | 2024-11-27 | 2025-01-10 |  | 101d | 0d | start no earlier than 2024-11-27 |  |
| 29 | 2.8 | 2025-2026 Winter Work Shut Down (In specs) |  | 33d | 2025-11-26 | 2026-01-09 |  | 65d | 0d | start no earlier than 2025-11-26 |  |
| 30 | 2.9 | 2026-2027 Winter Work Shut Down (In specs) |  | 33d | 2026-11-26 | 2027-01-11 |  | 36d | 0d | start no earlier than 2026-11-26 |  |

| ID | WBS | Task | Duration | Start | Finish | Predecessors | Total slack | Free slack |
| --- | --- | --- | --- | --- | --- | --- | --- | --- |
| 31 | 2.10 | **MOBILIZATION** | 10d | 2023-03-27 | 2023-04-07 | 9 | 185d | 0d |
| 32 | 2.10.1 | Establish Project Field Office | 10d | 2023-03-27 | 2023-04-07 |  | 185d |  |
| 33 | 2.10.2 | Establish Project Laydown Area | 10d | 2023-03-27 | 2023-04-07 |  | 185d |  |
| 34 | 2.10.3 | Establish BMPs at material disposal area | 5d | 2023-03-27 | 2023-03-31 |  | 190d |  |
| 35 | 2.11 | **SE 148th - ECL: CONST SOUTH SIDE WIDENING** | 383d | 2023-04-10 | 2024-09-25 |  | 185d | 145d |
| 36 | 2.11.1 | **Stage 1: Temporary Paving** | 15d | 2023-04-10 | 2023-04-28 | 31 | 185d | 0d |
| 37 | 2.11.1.1 | Place Construction TCD | 1d | 2023-04-10 | 2023-04-10 |  | 185d | 0d |
| 38 | 2.11.1.2 | Place Erosion Control Measures | 1d | 2023-04-11 | 2023-04-11 | 37 | 198d |  |
| 39 | 2.11.1.3 | Install Temporary Fencing for Tree Protection | 1d | 2023-04-11 | 2023-04-11 | 37 | 185d | 0d |
| 40 | 2.11.1.4 | Saw Cut Existing Shoulder & Pavement Removal | 1d | 2023-04-11 | 2023-04-11 | 37 | 185d | 0d |
| 41 | 2.11.1.5 | Earthwork | 4d | 2023-04-12 | 2023-04-17 | 39, 40 | 185d | 0d |
| 42 | 2.11.1.6 | Adjust Water Meters and Existing Inlets to Interim Grades | 4d | 2023-04-18 | 2023-04-21 | 41 | 186d | 1d |
| 43 | 2.11.1.7 | Place Geotextile/ Agg Base | 2d | 2023-04-18 | 2023-04-19 | 41 | 185d | 0d |
| 44 | 2.11.1.8 | Survey and Acceptance | 3d | 2023-04-20 | 2023-04-24 | 43 | 185d | 0d |
| 45 | 2.11.1.9 | Temporary Paving | 3d | 2023-04-25 | 2023-04-27 | 44, 42 | 185d | 0d |
| 46 | 2.11.1.10 | Shift Traffic | 1d | 2023-04-28 | 2023-04-28 | 45 | 185d |  |
| 47 | 2.11.2 | **South Side US-26 Widening** | 285d | 2023-05-01 | 2024-05-31 | 36 | 185d |  |
| 48 | 2.11.2.1 | Place Construction Signing | 1d | 2023-05-01 | 2023-05-01 |  | 185d | 0d |
| 49 | 2.11.2.2 | Remove/ Cover Existing Striping, Install Temporary Striping | 1d | 2023-05-02 | 2023-05-02 | 48 | 185d | 0d |
| 50 | 2.11.2.3 | Place Erosion Control Measures | 1d | 2023-05-03 | 2023-05-03 | 49 | 709d |  |
| 51 | 2.11.2.4 | Saw Cut Existing Shoulder & Pavement Removal | 2d | 2023-05-03 | 2023-05-04 | 49 | 185d | 0d |
| 52 | 2.11.2.5 | First Blocks of Earthwork | 4d | 2023-05-05 | 2023-05-10 | 51 | 185d | 2d |
| 53 | 2.11.2.6 | **Stage 2 Phase 1: Reach 1 of Water Relocation - SE 148th Ave to SE 153rd Ave** | 44d | 2023-05-15 | 2023-07-13 | 52 | 183d |  |
| 54 | 2.11.2.6.1 | water main | 9d | 2023-05-15 | 2023-05-25 | 23 | 183d | 0d |
| 55 | 2.11.2.6.2 | water service lines | 5d | 2023-05-23 | 2023-05-29 | 54FF+2d | 183d | 0d |
| 56 | 2.11.2.6.3 | hydrants | 4d | 2023-05-26 | 2023-05-31 | 54 | 689d |  |
| 57 | 2.11.2.6.4 | primary flushing and pressure testing | 1d | 2023-05-30 | 2023-05-30 | 55 | 183d | 0d |
| 58 | 2.11.2.6.5 | testing readiness notice to PWB | 2d | 2023-05-31 | 2023-06-01 | 57 | 183d | 0d |
| 59 | 2.11.2.6.6 | PWB forces pressure testing | 2d | 2023-06-02 | 2023-06-05 | 58 | 183d | 0d |
| 60 | 2.11.2.6.7 | PWB forces witness & sampling for bacteriological testing | 1d | 2023-06-06 | 2023-06-06 | 59 | 183d | 0d |
| 61 | 2.11.2.6.8 | PWB forces lab testing (1st & 2nd tests) | 2d | 2023-06-07 | 2023-06-08 | 60 | 183d | 0d |
| 62 | 2.11.2.6.9 | meter readiness notice to PWB | 5d | 2023-06-23 | 2023-06-29 | 61, 65FF | 658d | 0d |
| 63 | 2.11.2.6.10 | PWB forces locates | 3d | 2023-06-09 | 2023-06-13 | 61 | 183d | 0d |
| 64 | 2.11.2.6.11 | PWB forces main tie ins (6 connections incl cross streets) | 12d | 2023-06-14 | 2023-06-29 | 63 | 183d | 0d |
| 65 | 2.11.2.6.12 | backside plumbing on service lines | 5d | 2023-06-23 | 2023-06-29 | 55, 64FF | 658d | 0d |
| 66 | 2.11.2.6.13 | PWB Forces Water Meter Installation (14 meters) | 2d | 2023-06-30 | 2023-07-03 | 65, 62 | 658d | 0d |
| 67 | 2.11.2.6.14 | disconnect readiness notice to PWB | 2d | 2023-07-04 | 2023-07-05 | 66 | 658d | 0d |
| 68 | 2.11.2.6.15 | PWB forces disconnection (6 connections incl cross streets) | 6d | 2023-07-06 | 2023-07-13 | 67 | 658d |  |

| ID | WBS | Task | Duration | Start | Finish | Predecessors | Total slack | Free slack |
| --- | --- | --- | --- | --- | --- | --- | --- | --- |
| 69 | 2.11.2.7 | **Stage 2 Phase 1: Reach 2 of Water Relocation - SE 153rd Ave to SE 157th Ave** | 39d | 2023-07-04 | 2023-08-25 | 64FS+2d | 183d |  |
| 70 | 2.11.2.7.1 | water main | 7d | 2023-07-04 | 2023-07-12 |  | 183d | 0d |
| 71 | 2.11.2.7.2 | water service lines | 4d | 2023-07-11 | 2023-07-14 | 70FF+2d | 183d | 0d |
| 72 | 2.11.2.7.3 | hydrants | 2d | 2023-07-13 | 2023-07-14 | 70 | 657d |  |
| 73 | 2.11.2.7.4 | preliminary flushing and pressure testing | 1d | 2023-07-17 | 2023-07-17 | 71 | 183d | 0d |
| 74 | 2.11.2.7.5 | testing readiness notice to PWB | 2d | 2023-07-18 | 2023-07-19 | 73 | 183d | 0d |
| 75 | 2.11.2.7.6 | PWB forces pressure testing | 2d | 2023-07-20 | 2023-07-21 | 74 | 183d | 0d |
| 76 | 2.11.2.7.7 | PWB forces witness & sampling for bacteriological testing | 1d | 2023-07-24 | 2023-07-24 | 75 | 183d | 0d |
| 77 | 2.11.2.7.8 | PWB forces lab testing (1st & 2nd tests) | 2d | 2023-07-25 | 2023-07-26 | 76 | 183d | 0d |
| 78 | 2.11.2.7.9 | meter readiness notice to PWB | 5d | 2023-08-08 | 2023-08-14 | 77, 81FF | 627d | 0d |
| 79 | 2.11.2.7.10 | PWB forces locates | 3d | 2023-07-27 | 2023-07-31 | 77 | 183d | 0d |
| 80 | 2.11.2.7.11 | PWB forces main tie ins (5 connections incl cross streets) | 10d | 2023-08-01 | 2023-08-14 | 79 | 183d | 0d |
| 81 | 2.11.2.7.12 | backside plumbing on service lines | 4d | 2023-08-09 | 2023-08-14 | 80FF, 71 | 627d | 0d |
| 82 | 2.11.2.7.13 | PWB Forces Water Meter Installation (13 meters) | 2d | 2023-08-15 | 2023-08-16 | 81, 78 | 627d | 0d |
| 83 | 2.11.2.7.14 | disconnect readiness notice to PWB | 2d | 2023-08-17 | 2023-08-18 | 82 | 627d | 0d |
| 84 | 2.11.2.7.15 | PWB forces disconnection (5 connections incl cross streets) | 5d | 2023-08-21 | 2023-08-25 | 83 | 627d |  |
| 85 | 2.11.2.8 | **Stage 2 Phase 1: Reach 3 of Water Relocation - SE 157th Ave to SE 160th Ave** | 32d | 2023-08-17 | 2023-09-29 | 80FS+2d | 183d |  |
| 86 | 2.11.2.8.1 | water main | 6d | 2023-08-17 | 2023-08-24 |  | 183d | 0d |
| 87 | 2.11.2.8.2 | water service lines | 3d | 2023-08-24 | 2023-08-28 | 86FF+2d | 183d | 0d |
| 88 | 2.11.2.8.3 | hydrants | 2d | 2023-08-25 | 2023-08-28 | 86 | 626d |  |
| 89 | 2.11.2.8.4 | peliminary flushing and pressure testing | 1d | 2023-08-29 | 2023-08-29 | 87 | 183d | 0d |
| 90 | 2.11.2.8.5 | testing readiness notice to PWB | 2d | 2023-08-30 | 2023-08-31 | 89 | 183d | 0d |
| 91 | 2.11.2.8.6 | PWB forces pressure testing | 2d | 2023-09-01 | 2023-09-04 | 90 | 183d | 0d |
| 92 | 2.11.2.8.7 | PWB forces witness & sampling for bacteriological testing | 1d | 2023-09-05 | 2023-09-05 | 91 | 183d | 0d |
| 93 | 2.11.2.8.8 | PWB forces lab testing (1st & 2nd tests) | 2d | 2023-09-06 | 2023-09-07 | 92 | 183d | 0d |
| 94 | 2.11.2.8.9 | meter readiness notice to PWB | 5d | 2023-09-14 | 2023-09-20 | 97FF, 93 | 602d | 0d |
| 95 | 2.11.2.8.10 | PWB forces locates | 3d | 2023-09-08 | 2023-09-12 | 93 | 183d | 0d |
| 96 | 2.11.2.8.11 | PWB forces main tie ins (3 connections incl cross streets) | 6d | 2023-09-13 | 2023-09-20 | 95 | 183d | 0d |
| 97 | 2.11.2.8.12 | backside plumbing on service lines | 5d | 2023-09-14 | 2023-09-20 | 96FF, 87 | 602d | 0d |
| 98 | 2.11.2.8.13 | PWB Forces Water Meter Installation (14 meters) | 2d | 2023-09-21 | 2023-09-22 | 97, 94 | 602d | 0d |
| 99 | 2.11.2.8.14 | disconnect readiness notice to PWB | 2d | 2023-09-25 | 2023-09-26 | 98 | 602d | 0d |
| 100 | 2.11.2.8.15 | PWB forces disconnection (3 connections incl cross streets) | 3d | 2023-09-27 | 2023-09-29 | 99 | 602d |  |

| ID | WBS | Task | Type | Duration | Start | Finish | Predecessors | Total slack | Free slack |
| --- | --- | --- | --- | --- | --- | --- | --- | --- | --- |
| 101 | 2.11.2.9 | **Stage 2 Phase 1: Reach 4 of Water Relocation - SE 160th Ave to SE 162nd Ave** |  | 24d | 2023-09-25 | 2023-10-26 | 96FS+2d | 183d |  |
| 102 | 2.11.2.9.1 | water main |  | 2d | 2023-09-25 | 2023-09-26 |  | 183d | 0d |
| 103 | 2.11.2.9.2 | water service lines |  | 2d | 2023-09-27 | 2023-09-28 | 102FF+2d | 183d | 0d |
| 104 | 2.11.2.9.3 | hydrants | milestone | 0d | 2023-09-26 | 2023-09-26 | 102 | 605d |  |
| 105 | 2.11.2.9.4 | preliminary flushing and pressure testing |  | 1d | 2023-09-29 | 2023-09-29 | 103 | 183d | 0d |
| 106 | 2.11.2.9.5 | testing readiness notice to PWB |  | 2d | 2023-10-02 | 2023-10-03 | 105 | 183d | 0d |
| 107 | 2.11.2.9.6 | PWB forces pressure testing |  | 2d | 2023-10-04 | 2023-10-05 | 106 | 183d | 0d |
| 108 | 2.11.2.9.7 | PWB forces witness & sampling for bacteriological testing |  | 1d | 2023-10-06 | 2023-10-06 | 107 | 183d | 0d |
| 109 | 2.11.2.9.8 | PWB forces lab testing (1st & 2nd tests) |  | 2d | 2023-10-09 | 2023-10-10 | 108 | 183d | 0d |
| 110 | 2.11.2.9.9 | meter readiness notice to PWB |  | 5d | 2023-10-13 | 2023-10-19 | 109, 113FF | 183d | 0d |
| 111 | 2.11.2.9.10 | PWB forces locates |  | 3d | 2023-10-11 | 2023-10-13 | 109 | 183d | 0d |
| 112 | 2.11.2.9.11 | PWB forces main tie ins (2 connections) |  | 4d | 2023-10-16 | 2023-10-19 | 111 | 183d | 0d |
| 113 | 2.11.2.9.12 | backside plumbing on service lines |  | 2d | 2023-10-18 | 2023-10-19 | 112FF, 103 | 183d | 0d |
| 114 | 2.11.2.9.13 | PWB Forces Water Meter Installation (6 meters) |  | 1d | 2023-10-20 | 2023-10-20 | 112, 110 | 183d | 0d |
| 115 | 2.11.2.9.14 | disconnect readiness notice to PWB |  | 2d | 2023-10-23 | 2023-10-24 | 114 | 183d | 0d |
| 116 | 2.11.2.9.15 | PWB forces disconnection (2 connections) |  | 2d | 2023-10-25 | 2023-10-26 | 115 | 183d | 0d |
| 117 | 2.11.2.10 | Stage 3 Phase 2: Install South Side & Some North Side Drywells and Sediment MHs |  | 30d | 2023-09-22 | 2023-11-02 | 116FF+5d | 388d | 0d |
| 118 | 2.11.2.11 | **Stage 2 Phase 1: Water Relocations Outside of Reaches** |  | 109d | 2023-10-27 | 2024-03-27 | 116 | 183d | 0d |
| 119 | 2.11.2.11.1 | **SE 164th Ave** |  | 21d | 2024-01-23 | 2024-02-20 | 155 | 139d |  |
| 120 | 2.11.2.11.1.1 | water main |  | 2d | 2024-01-23 | 2024-01-24 |  | 139d | 0d |
| 121 | 2.11.2.11.1.2 | hydrant |  | 1d | 2024-01-25 | 2024-01-25 | 120 | 424d |  |
| 122 | 2.11.2.11.1.3 | preliminary flushing and pressure testing |  | 1d | 2024-01-25 | 2024-01-25 | 120 | 139d | 0d |
| 123 | 2.11.2.11.1.4 | testing readiness notice to PWB |  | 2d | 2024-01-26 | 2024-01-29 | 122 | 139d | 0d |
| 124 | 2.11.2.11.1.5 | PWB forces pressure testing |  | 2d | 2024-01-30 | 2024-01-31 | 123 | 139d | 0d |
| 125 | 2.11.2.11.1.6 | PWB forces witness & sampling for bacteriological testing |  | 1d | 2024-02-01 | 2024-02-01 | 124 | 139d | 0d |
| 126 | 2.11.2.11.1.7 | PWB forces lab testing (1st & 2nd tests) |  | 2d | 2024-02-02 | 2024-02-05 | 125 | 139d | 0d |
| 127 | 2.11.2.11.1.8 | PWB forces locates |  | 3d | 2024-02-06 | 2024-02-08 | 126 | 139d | 0d |
| 128 | 2.11.2.11.1.9 | PWB forces main tie ins (2 connections) |  | 4d | 2024-02-09 | 2024-02-14 | 127 | 139d | 0d |
| 129 | 2.11.2.11.1.10 | disconnect readiness notice to PWB |  | 2d | 2024-02-15 | 2024-02-16 | 128 | 380d | 0d |
| 130 | 2.11.2.11.1.11 | PWB forces disconnection (2 connections) |  | 2d | 2024-02-19 | 2024-02-20 | 129 | 380d | 0d |

| ID | WBS | Task | Duration | Start | Finish | Predecessors | Total slack | Free slack |
| --- | --- | --- | --- | --- | --- | --- | --- | --- |
| 131 | 2.11.2.11.2 | **SE 166th Ave** | 30d | 2024-01-30 | 2024-03-11 | 123 | 146d |  |
| 132 | 2.11.2.11.2.1 | water main | 2d | 2024-01-30 | 2024-01-31 |  | 146d | 0d |
| 133 | 2.11.2.11.2.2 | hydrant | 1d | 2024-02-01 | 2024-02-01 | 132 | 419d |  |
| 134 | 2.11.2.11.2.3 | preliminary flushing and pressure testing | 1d | 2024-02-01 | 2024-02-01 | 132 | 146d | 0d |
| 135 | 2.11.2.11.2.4 | testing readiness notice to PWB | 2d | 2024-02-02 | 2024-02-05 | 134 | 146d | 7d |
| 136 | 2.11.2.11.2.5 | PWB forces pressure testing | 2d | 2024-02-15 | 2024-02-16 | 135, 128 | 139d | 0d |
| 137 | 2.11.2.11.2.6 | PWB forces witness & sampling for bacteriological testing | 1d | 2024-02-21 | 2024-02-21 | 136, 130 | 380d | 0d |
| 138 | 2.11.2.11.2.7 | PWB forces lab testing (1st & 2nd tests) | 2d | 2024-02-22 | 2024-02-23 | 137 | 380d | 0d |
| 139 | 2.11.2.11.2.8 | PWB forces locates | 3d | 2024-02-26 | 2024-02-28 | 138 | 380d | 0d |
| 140 | 2.11.2.11.2.9 | PWB forces main tie ins (2 connections) | 4d | 2024-02-29 | 2024-03-05 | 139 | 380d | 0d |
| 141 | 2.11.2.11.2.10 | disconnect readiness notice to PWB | 2d | 2024-03-06 | 2024-03-07 | 140 | 392d | 0d |
| 142 | 2.11.2.11.2.11 | PWB forces disconnection (2 connections) | 2d | 2024-03-08 | 2024-03-11 | 141 | 392d |  |
| 143 | 2.11.2.11.3 | **SE 170th Ave** | 28d | 2024-02-19 | 2024-03-27 | 136 | 139d |  |
| 144 | 2.11.2.11.3.1 | water main | 2d | 2024-02-19 | 2024-02-20 |  | 139d | 0d |
| 145 | 2.11.2.11.3.2 | hydrant | 1d | 2024-02-21 | 2024-02-21 | 144 | 405d |  |
| 146 | 2.11.2.11.3.3 | preliminary flushing and pressure testing | 1d | 2024-02-21 | 2024-02-21 | 144 | 139d | 0d |
| 147 | 2.11.2.11.3.4 | testing readiness notice to PWB | 2d | 2024-02-22 | 2024-02-23 | 146 | 139d | 0d |
| 148 | 2.11.2.11.3.5 | PWB forces pressure testing | 2d | 2024-03-06 | 2024-03-07 | 147, 140 | 380d | 0d |
| 149 | 2.11.2.11.3.6 | PWB forces witness & sampling for bacteriological testing | 1d | 2024-03-08 | 2024-03-08 | 148 | 380d | 0d |
| 150 | 2.11.2.11.3.7 | PWB forces lab testing (1st & 2nd tests) | 2d | 2024-03-11 | 2024-03-12 | 149 | 380d | 0d |
| 151 | 2.11.2.11.3.8 | PWB forces locates | 3d | 2024-03-13 | 2024-03-15 | 150 | 380d | 0d |
| 152 | 2.11.2.11.3.9 | PWB forces main tie ins (2 connections) | 4d | 2024-03-18 | 2024-03-21 | 151 | 380d | 0d |
| 153 | 2.11.2.11.3.10 | disconnect readiness notice to PWB | 2d | 2024-03-22 | 2024-03-25 | 152 | 380d | 0d |
| 154 | 2.11.2.11.3.11 | PWB forces disconnection (2 connections) | 2d | 2024-03-26 | 2024-03-27 | 153 | 380d |  |

| ID | WBS | Task | Duration | Start | Finish | Predecessors | Total slack | Free slack |
| --- | --- | --- | --- | --- | --- | --- | --- | --- |
| 155 | 2.11.2.11.4 | **Meters & hydrants from SE 162nd to ECL** | 62d | 2023-10-27 | 2024-01-22 |  | 139d | 0d |
| 156 | 2.11.2.11.4.1 | PWB forces meter box relocation (20 meters) | 10d | 2023-10-27 | 2023-11-09 |  | 183d | 44d |
| 157 | 2.11.2.11.4.2 | PWB forces hydrant relocation (6 hydrants) | 8d | 2024-01-11 | 2024-01-22 | 156, 27 | 139d |  |
| 158 | 2.11.2.12 | Stage 3 Phase 2: Install South Side Storm Sewer Pipe | 18d | 2023-10-17 | 2023-11-09 | 117FF+5d | 388d | 0d |
| 159 | 2.11.2.13 | Finish Placing South Side Geotextile/ Agg Base | 1d | 2023-11-10 | 2023-11-10 | 158 | 405d | 0d |
| 160 | 2.11.2.14 | Stage 3 Phase 2: Install Storm Inlets | 30d | 2024-01-11 | 2024-02-21 | 158, 27 | 344d | 0d |
| 161 | 2.11.2.15 | Stage 3 Phase 2: Set Forms & Stringline for Curb & Concrete Pavement | 2d | 2024-02-22 | 2024-02-23 | 160 | 344d | 0d |
| 162 | 2.11.2.16 | Stage 3 Phase 2: Place First Blocks of Curb & Bus Stop Concrete Pavement | 6d | 2024-02-26 | 2024-03-04 | 161 | 344d | 0d |
| 163 | 2.11.2.17 | Stage 3 Phase 2: Cure Curb & Bus Stop Concrete Pavement | 5d | 2024-03-05 | 2024-03-11 | 162 | 485d | 12d |
| 164 | 2.11.2.18 | Stage 3 Phase 2: Paving & Patching | 1d | 2024-03-28 | 2024-03-28 | 163, 118 | 473d |  |
| 165 | 2.11.2.19 | Stage 3 Phase 2: Install Signal & Light Pole Foundations & Conduit | 20d | 2023-11-13 | 2023-12-08 | 52, 159 | 405d | 61d |
| 166 | 2.11.2.20 | Stage 3 Phase 1: Install Temporary Signals | 60d | 2023-08-14 | 2023-11-03 | 21 | 532d | 171d |
| 167 | 2.11.2.21 | Stage 3 Phase 2: Set Back of Walk Form | 1d | 2024-03-05 | 2024-03-05 | 165, 162 | 344d | 0d |
| 168 | 2.11.2.22 | Stage 3 Phase 2: Place Sidewalk & Driveways | 55d | 2024-03-06 | 2024-05-21 | 167, 118FF+3d | 344d | 0d |
| 169 | 2.11.2.23 | Stage 3 Phase 2: Cure Sidewalk & Driveways | 3d | 2024-05-22 | 2024-05-24 | 168 | 361d | 0d |
| 170 | 2.11.2.24 | Stage 3 Phase 2: Complete Planter Strips | 5d | 2024-05-27 | 2024-05-31 | 169 | 427d |  |
| 171 | 2.11.2.25 | Stage 3 Phase 2: Driveway & Site Paving | 5d | 2024-05-27 | 2024-05-31 | 169 | 427d |  |
| 172 | 2.11.3 | **Sidewalk Along US-26 at Intersections** | 30d | 2024-05-08 | 2024-06-18 |  | 344d | 0d |
| 173 | 2.11.3.1 | Place Construction Signing | 1d | 2024-05-08 | 2024-05-08 | 168FS-10d | 344d | 0d |
| 174 | 2.11.3.2 | Place Erosion Control Measures | 1d | 2024-05-09 | 2024-05-09 | 173 | 344d | 0d |
| 175 | 2.11.3.3 | Construct Temp Pedestrian Accessible Routes | 4d | 2024-05-10 | 2024-05-15 | 174 | 344d | 0d |
| 176 | 2.11.3.4 | Shift Traffic to TPAR | 1d | 2024-05-16 | 2024-05-16 | 175 | 344d | 0d |
| 177 | 2.11.3.5 | Saw Cut Existing Shoulder & Pavement Removal | 2d | 2024-05-17 | 2024-05-20 | 176 | 344d | 0d |
| 178 | 2.11.3.6 | Earthwork | 2d | 2024-05-21 | 2024-05-22 | 175, 177 | 344d | 0d |
| 179 | 2.11.3.7 | Place Geotextile/ Agg Base | 1d | 2024-05-23 | 2024-05-23 | 178 | 344d | 0d |
| 180 | 2.11.3.8 | Survey and Acceptance | 3d | 2024-05-24 | 2024-05-28 | 179 | 344d | 0d |
| 181 | 2.11.3.9 | Set Forms for Curb | 1d | 2024-05-29 | 2024-05-29 | 180, 161 | 344d | 0d |
| 182 | 2.11.3.10 | Place Curb | 2d | 2024-05-30 | 2024-05-31 | 181 | 344d | 0d |
| 183 | 2.11.3.11 | Cure Curb | 3d | 2024-06-03 | 2024-06-05 | 182 | 344d | 0d |
| 184 | 2.11.3.12 | Paving & Patching | 1d | 2024-06-06 | 2024-06-06 | 183 | 344d | 0d |
| 185 | 2.11.3.13 | Set Back of Walk Form | 1d | 2024-06-05 | 2024-06-05 | 180, 183FS-1d | 345d | 1d |
| 186 | 2.11.3.14 | Place Sidewalk & Ped Ramp | 5d | 2024-06-07 | 2024-06-13 | 184, 185 | 344d | 0d |
| 187 | 2.11.3.15 | Cure Sidewalk & Ped Ramp | 3d | 2024-06-14 | 2024-06-18 | 186 | 344d |  |

| ID | WBS | Task | Duration | Start | Finish | Predecessors | Total slack | Free slack |
| --- | --- | --- | --- | --- | --- | --- | --- | --- |
| 188 | 2.11.4 | **Sidewalk Along Sidestreets & Intersections TPAR Area** | 29d | 2024-06-19 | 2024-07-29 | 172, 169 | 344d |  |
| 189 | 2.11.4.1 | Place Construction Signing | 1d | 2024-06-19 | 2024-06-19 |  | 344d | 0d |
| 190 | 2.11.4.2 | Construct Another Set of Temp Pedestrian Accessible Routes | 4d | 2024-06-20 | 2024-06-25 | 189 | 344d | 0d |
| 191 | 2.11.4.3 | Shift Traffic to TPAR | 1d | 2024-06-26 | 2024-06-26 | 190 | 344d | 0d |
| 192 | 2.11.4.4 | Saw Cut Existing Shoulder & Pavement Removal | 2d | 2024-06-27 | 2024-06-28 | 191 | 344d | 0d |
| 193 | 2.11.4.5 | Earthwork | 2d | 2024-07-01 | 2024-07-02 | 190, 192 | 344d | 0d |
| 194 | 2.11.4.6 | Place Geotextile/ Agg Base | 1d | 2024-07-03 | 2024-07-03 | 193 | 344d | 0d |
| 195 | 2.11.4.7 | Survey and Acceptance | 3d | 2024-07-04 | 2024-07-08 | 194 | 344d | 0d |
| 196 | 2.11.4.8 | Set Forms for Curb | 1d | 2024-07-09 | 2024-07-09 | 195 | 344d | 0d |
| 197 | 2.11.4.9 | Place Curb | 2d | 2024-07-10 | 2024-07-11 | 196 | 344d | 0d |
| 198 | 2.11.4.10 | Cure Curb | 3d | 2024-07-12 | 2024-07-16 | 197 | 344d | 0d |
| 199 | 2.11.4.11 | Paving & Patching | 1d | 2024-07-17 | 2024-07-17 | 198 | 344d | 0d |
| 200 | 2.11.4.12 | Set Back of Walk Form | 1d | 2024-07-16 | 2024-07-16 | 195, 198FS-1d | 345d | 1d |
| 201 | 2.11.4.13 | Place Sidewalk & Ped Ramp | 5d | 2024-07-18 | 2024-07-24 | 199, 200 | 344d | 0d |
| 202 | 2.11.4.14 | Cure Sidewalk & Ped Ramp | 3d | 2024-07-25 | 2024-07-29 | 201 | 386d |  |
| 203 | 2.11.5 | **Sidewalk in Intersection Radii** | 30d | 2024-07-25 | 2024-09-04 | 201 | 344d | 0d |
| 204 | 2.11.5.1 | Place Construction Signing | 1d | 2024-07-25 | 2024-07-25 | 166 | 344d | 0d |
| 205 | 2.11.5.2 | Construct Another Set of Temp Pedestrian Accessible Routes | 3d | 2024-07-26 | 2024-07-30 | 204 | 344d | 0d |
| 206 | 2.11.5.3 | Shift Traffic to TPAR | 1d | 2024-07-31 | 2024-07-31 | 205 | 344d | 0d |
| 207 | 2.11.5.4 | Saw Cut Existing Shoulder & Pavement Removal | 2d | 2024-08-01 | 2024-08-02 | 206 | 344d | 0d |
| 208 | 2.11.5.5 | Earthwork | 2d | 2024-08-05 | 2024-08-06 | 205, 207 | 344d | 0d |
| 209 | 2.11.5.6 | Place Geotextile/ Agg Base | 1d | 2024-08-07 | 2024-08-07 | 208 | 344d | 0d |
| 210 | 2.11.5.7 | Survey and Acceptance | 3d | 2024-08-08 | 2024-08-12 | 209 | 344d | 0d |
| 211 | 2.11.5.8 | Set Forms for Curb | 1d | 2024-08-13 | 2024-08-13 | 210 | 344d | 0d |
| 212 | 2.11.5.9 | Place Curb | 2d | 2024-08-14 | 2024-08-15 | 211 | 344d | 0d |
| 213 | 2.11.5.10 | Cure Curb | 3d | 2024-08-16 | 2024-08-20 | 212 | 344d | 0d |
| 214 | 2.11.5.11 | Paving & Patching | 1d | 2024-08-21 | 2024-08-21 | 213 | 344d | 0d |
| 215 | 2.11.5.12 | Set Back of Walk Form | 1d | 2024-08-20 | 2024-08-20 | 210, 213FS-1d | 345d | 1d |
| 216 | 2.11.5.13 | Place Sidewalk & Ped Ramp | 5d | 2024-08-22 | 2024-08-28 | 214, 215 | 344d | 0d |
| 217 | 2.11.5.14 | Cure Sidewalk & Ped Ramp | 3d | 2024-08-29 | 2024-09-02 | 216 | 344d | 0d |
| 218 | 2.11.5.15 | Remove TPARs | 2d | 2024-09-03 | 2024-09-04 | 217 | 344d |  |
| 219 | 2.11.6 | 2023 Project Contingency Days (weather) | 15d | 2024-09-05 | 2024-09-25 | 203 | 344d |  |

| ID | WBS | Task | Type | Duration | Start | Finish | Predecessors | Total slack | Free slack |
| --- | --- | --- | --- | --- | --- | --- | --- | --- | --- |
| 220 | 2.12 | **SE 136th - SE 148th AVENUE: CONST SOUTH SIDE WIDENING** |  | 317d | 2024-01-30 | 2025-04-16 |  | 139d | 0d |
| 221 | 2.12.1 | **Stage 1: Temporary Paving** |  | 15d | 2024-01-30 | 2024-02-19 |  | 139d | 0d |
| 222 | 2.12.1.1 | Place Construction TCD |  | 1d | 2024-01-30 | 2024-01-30 | 147FS-19d | 139d | 0d |
| 223 | 2.12.1.2 | Place Erosion Control Measures |  | 1d | 2024-01-31 | 2024-01-31 | 222 | 139d | 0d |
| 224 | 2.12.1.3 | Install Temporary Fencing for Tree Protection |  | 2d | 2024-01-31 | 2024-02-01 | 222 | 140d | 1d |
| 225 | 2.12.1.4 | Saw Cut Existing Shoulder & Pavement Removal |  | 2d | 2024-02-01 | 2024-02-02 | 223 | 139d | 0d |
| 226 | 2.12.1.5 | Earthwork |  | 4d | 2024-02-05 | 2024-02-08 | 224, 225 | 139d | 0d |
| 227 | 2.12.1.6 | Place Geotextile/ Agg Base |  | 1d | 2024-02-09 | 2024-02-09 | 226 | 139d | 0d |
| 228 | 2.12.1.7 | Adjust Water Meters and Existing Inlets to Interim Grades |  | 3d | 2024-02-12 | 2024-02-14 | 227 | 139d | 0d |
| 229 | 2.12.1.8 | Survey and Acceptance |  | 3d | 2024-02-12 | 2024-02-14 | 227 | 139d | 0d |
| 230 | 2.12.1.9 | Temporary Paving |  | 2d | 2024-02-15 | 2024-02-16 | 228, 229 | 139d | 0d |
| 231 | 2.12.1.10 | Shift Traffic |  | 1d | 2024-02-19 | 2024-02-19 | 230 | 139d |  |
| 232 | 2.12.2 | **South Side US-26 Widening** |  | 173d | 2024-02-20 | 2024-10-17 | 221 | 139d |  |
| 233 | 2.12.2.1 | Place Construction Signing |  | 1d | 2024-02-20 | 2024-02-20 |  | 139d | 0d |
| 234 | 2.12.2.2 | Remove/ Cover Existing Striping, Install Temporary Striping |  | 1d | 2024-02-21 | 2024-02-21 | 233 | 139d | 0d |
| 235 | 2.12.2.3 | Place Erosion Control Measures |  | 1d | 2024-02-22 | 2024-02-22 | 234 | 139d | 0d |
| 236 | 2.12.2.4 | Saw Cut Existing Shoulder & Pavement Removal |  | 2d | 2024-02-22 | 2024-02-23 | 234 | 493d | 0d |
| 237 | 2.12.2.5 | First Blocks of Earthwork |  | 4d | 2024-02-26 | 2024-02-29 | 236 | 493d |  |
| 238 | 2.12.2.6 | **Stage 2 Phase 1: Reach 1 of Water Relocation - SE 148th Ave to SE 144th Ave** |  | 38d | 2024-02-23 | 2024-04-16 | 235 | 139d |  |
| 239 | 2.12.2.6.1 | water main |  | 7d | 2024-02-23 | 2024-03-04 |  | 139d | 0d |
| 240 | 2.12.2.6.2 | water service lines |  | 2d | 2024-03-05 | 2024-03-06 | 239FF+2d | 139d | 0d |
| 241 | 2.12.2.6.3 | hydrants | milestone | 0d | 2024-03-04 | 2024-03-04 | 239 | 491d |  |
| 242 | 2.12.2.6.4 | preliminary flushing and pressure testing |  | 1d | 2024-03-07 | 2024-03-07 | 240 | 139d | 0d |
| 243 | 2.12.2.6.5 | testing readiness notice to PWB |  | 2d | 2024-03-08 | 2024-03-11 | 242 | 139d | 0d |
| 244 | 2.12.2.6.6 | PWB forces pressure testing |  | 2d | 2024-03-12 | 2024-03-13 | 243 | 139d | 0d |
| 245 | 2.12.2.6.7 | PWB forces witness & sampling for bacteriological testing |  | 1d | 2024-03-14 | 2024-03-14 | 244 | 139d | 0d |
| 246 | 2.12.2.6.8 | PWB forces lab testing |  | 2d | 2024-03-15 | 2024-03-18 | 245 | 139d | 0d |
| 247 | 2.12.2.6.9 | meter readiness notice to PWB |  | 5d | 2024-03-19 | 2024-03-25 | 246 | 468d | 8d |
| 248 | 2.12.2.6.10 | PWB forces locates |  | 3d | 2024-03-19 | 2024-03-21 | 246 | 139d | 0d |
| 249 | 2.12.2.6.11 | PWB forces main tie ins (5 connections incl cross streets) |  | 10d | 2024-03-22 | 2024-04-04 | 248 | 139d | 0d |
| 250 | 2.12.2.6.12 | backside plumbing on service lines |  | 5d | 2024-03-29 | 2024-04-04 | 240, 249FF | 460d | 0d |
| 251 | 2.12.2.6.13 | PWB forces water meter installation (7 meters) |  | 1d | 2024-04-05 | 2024-04-05 | 247, 250 | 460d | 0d |
| 252 | 2.12.2.6.14 | disconnect readiness notice to PWB |  | 2d | 2024-04-08 | 2024-04-09 | 251 | 460d | 0d |
| 253 | 2.12.2.6.15 | PWB forces disconnection (5 connections incl cross streets) |  | 5d | 2024-04-10 | 2024-04-16 | 252 | 460d |  |

| ID | WBS | Task | Duration | Start | Finish | Predecessors | Total slack | Free slack |
| --- | --- | --- | --- | --- | --- | --- | --- | --- |
| 254 | 2.12.2.7 | **Stage 2 Phase 1: Reach 2 of Water Relocation - SE 144th Ave to SE 140th Ave** | 40d | 2024-04-09 | 2024-06-03 | 249FS+2d | 139d |  |
| 255 | 2.12.2.7.1 | water main | 9d | 2024-04-09 | 2024-04-19 |  | 139d | 0d |
| 256 | 2.12.2.7.2 | water service lines | 2d | 2024-04-22 | 2024-04-23 | 255FF+2d | 139d | 0d |
| 257 | 2.12.2.7.3 | hydrants | 1d | 2024-04-22 | 2024-04-22 | 255 | 456d |  |
| 258 | 2.12.2.7.4 | preliminary flushing and pressure testing | 1d | 2024-04-24 | 2024-04-24 | 256 | 139d | 0d |
| 259 | 2.12.2.7.5 | testing readiness notice to PWB | 2d | 2024-04-25 | 2024-04-26 | 258 | 139d | 0d |
| 260 | 2.12.2.7.6 | PWB forces pressure testing | 2d | 2024-04-29 | 2024-04-30 | 259 | 139d | 0d |
| 261 | 2.12.2.7.7 | PWB forces witness & sampling for bacteriological testing | 1d | 2024-05-01 | 2024-05-01 | 260 | 139d | 0d |
| 262 | 2.12.2.7.8 | PWB forces lab testing | 2d | 2024-05-02 | 2024-05-03 | 261 | 139d | 0d |
| 263 | 2.12.2.7.9 | meter readiness notice to PWB | 5d | 2024-05-06 | 2024-05-10 | 262 | 434d | 8d |
| 264 | 2.12.2.7.10 | PWB locates | 3d | 2024-05-06 | 2024-05-08 | 262 | 139d | 0d |
| 265 | 2.12.2.7.11 | PWB forces main tie ins (5 connections incl cross streets) | 10d | 2024-05-09 | 2024-05-22 | 264 | 139d | 0d |
| 266 | 2.12.2.7.12 | backside plumbing on service lines | 5d | 2024-05-16 | 2024-05-22 | 256, 265FF | 426d | 0d |
| 267 | 2.12.2.7.13 | PWB Forces Water Meter Installation (7 meters) | 1d | 2024-05-23 | 2024-05-23 | 263, 266 | 426d | 0d |
| 268 | 2.12.2.7.14 | disconnect readiness notice to PWB | 2d | 2024-05-24 | 2024-05-27 | 267 | 426d | 0d |
| 269 | 2.12.2.7.15 | PWB forces disconnection (5 connections incl cross streets) | 5d | 2024-05-28 | 2024-06-03 | 268 | 426d |  |
| 270 | 2.12.2.8 | **Stage 2 Phase 1: Reach 3 of Water Relocation - SE 140th Ave to SE 136th Ave** | 37d | 2024-05-27 | 2024-07-16 | 265FS+2d | 139d | 0d |
| 271 | 2.12.2.8.1 | water main | 8d | 2024-05-27 | 2024-06-05 |  | 139d | 0d |
| 272 | 2.12.2.8.2 | water service lines | 3d | 2024-06-05 | 2024-06-07 | 271FF+2d | 140d | 1d |
| 273 | 2.12.2.8.3 | hydrants | 3d | 2024-06-06 | 2024-06-10 | 271 | 139d | 0d |
| 274 | 2.12.2.8.4 | preliminary flushing and pressure testing | 1d | 2024-06-11 | 2024-06-11 | 272, 273 | 139d | 0d |
| 275 | 2.12.2.8.5 | testing readiness notice to PWB | 2d | 2024-06-12 | 2024-06-13 | 274 | 139d | 0d |
| 276 | 2.12.2.8.6 | PWB forces pressure testing | 2d | 2024-06-14 | 2024-06-17 | 275 | 139d | 0d |
| 277 | 2.12.2.8.7 | PWB forces witness & sampling for bacteriological testing | 1d | 2024-06-18 | 2024-06-18 | 276 | 139d | 0d |
| 278 | 2.12.2.8.8 | PWB forces lab testing | 2d | 2024-06-19 | 2024-06-20 | 277 | 139d | 0d |
| 279 | 2.12.2.8.9 | meter readiness notice to PWB | 5d | 2024-06-21 | 2024-06-27 | 278 | 145d | 6d |
| 280 | 2.12.2.8.10 | PWB locates | 3d | 2024-06-21 | 2024-06-25 | 278 | 139d | 0d |
| 281 | 2.12.2.8.11 | PWB forces main tie ins (4 connections incl cross streets) | 8d | 2024-06-26 | 2024-07-05 | 280 | 139d | 0d |
| 282 | 2.12.2.8.12 | backside plumbing on service lines | 6d | 2024-06-28 | 2024-07-05 | 272, 281FF | 139d | 0d |
| 283 | 2.12.2.8.13 | PWB Forces Water Meter Installation (10 meters) | 1d | 2024-07-08 | 2024-07-08 | 279, 282 | 139d | 0d |
| 284 | 2.12.2.8.14 | disconnect readiness notice to PWB | 2d | 2024-07-09 | 2024-07-10 | 283 | 139d | 0d |
| 285 | 2.12.2.8.15 | PWB forces disconnection (4 connections incl cross streets) | 4d | 2024-07-11 | 2024-07-16 | 284 | 139d | 0d |
| 286 | 2.12.2.9 | Stage 3 Phase 2: Install South Side & Some North Side Drywells and Sediment MHs | 15d | 2024-07-03 | 2024-07-23 | 285FF+5d | 235d | 0d |
| 287 | 2.12.2.10 | Stage 3 Phase 2: Install South Side Storm Sewer Pipe and MHs | 5d | 2024-07-24 | 2024-07-30 | 286FF+5d | 235d | 0d |
| 288 | 2.12.2.11 | Finish Placing South Side Geotextile/ Agg Base | 1d | 2024-07-31 | 2024-07-31 | 287 | 238d | 0d |
| 289 | 2.12.2.12 | Stage 3 Phase 2: Install Storm Inlets | 11d | 2024-07-31 | 2024-08-14 | 287 | 235d | 0d |
| 290 | 2.12.2.13 | Stage 3 Phase 2: Set Forms for Curb & Stringline & Concrete Pavement | 2d | 2024-08-15 | 2024-08-16 | 289 | 235d | 0d |
| 291 | 2.12.2.14 | Stage 3 Phase 2: Place First Blocks of Curb & Bus Stop Concrete Pavement | 6d | 2024-08-19 | 2024-08-26 | 290 | 235d | 0d |
| 292 | 2.12.2.15 | Stage 3 Phase 2: Cure Curb & Bus Stop Concrete Pavement | 5d | 2024-08-27 | 2024-09-02 | 291 | 235d | 0d |
| 293 | 2.12.2.16 | Stage 3 Phase 2: Paving & Patching | 1d | 2024-09-03 | 2024-09-03 | 292 | 360d |  |
| 294 | 2.12.2.17 | Stage 3 Phase 2: Install Signal & Light Pole Foundations & Conduit | 20d | 2024-08-01 | 2024-08-28 | 165, 288 | 238d | 3d |
| 295 | 2.12.2.18 | Stage 3 Phase 2: Set Back of Walk Form | 1d | 2024-09-03 | 2024-09-03 | 292, 294 | 235d | 0d |
| 296 | 2.12.2.19 | Stage 3 Phase 2: Place Sidewalk & Driveways | 24d | 2024-09-04 | 2024-10-07 | 295 | 235d | 0d |
| 297 | 2.12.2.20 | Stage 3 Phase 2: Cure Sidewalk & Driveways | 3d | 2024-10-08 | 2024-10-10 | 296 | 235d | 0d |
| 298 | 2.12.2.21 | Stage 3 Phase 2: Complete Planter Strips | 5d | 2024-10-11 | 2024-10-17 | 297 | 328d |  |
| 299 | 2.12.2.22 | Stage 3 Phase 2: Driveway Paving | 5d | 2024-10-11 | 2024-10-17 | 297 | 328d |  |

| ID | WBS | Task | Duration | Start | Finish | Predecessors | Total slack | Free slack |
| --- | --- | --- | --- | --- | --- | --- | --- | --- |
| 300 | 2.12.3 | **Sidewalk Along US-26 at Intersections** | 37d | 2024-09-24 | 2024-11-13 |  | 235d | 0d |
| 301 | 2.12.3.1 | Place Construction Signing | 1d | 2024-09-24 | 2024-09-24 | 296FS-10d | 242d | 0d |
| 302 | 2.12.3.2 | Place Erosion Control Measures | 1d | 2024-09-25 | 2024-09-25 | 301 | 242d | 0d |
| 303 | 2.12.3.3 | Construct Temp Pedestrian Accessible Routes | 4d | 2024-09-26 | 2024-10-01 | 302 | 242d | 7d |
| 304 | 2.12.3.4 | Shift Traffic to TPAR | 1d | 2024-10-11 | 2024-10-11 | 297, 303 | 235d | 0d |
| 305 | 2.12.3.5 | Saw Cut Existing Shoulder & Pavement Removal | 2d | 2024-10-14 | 2024-10-15 | 304 | 235d | 0d |
| 306 | 2.12.3.6 | Earthwork | 2d | 2024-10-16 | 2024-10-17 | 303, 305 | 235d | 0d |
| 307 | 2.12.3.7 | Place Geotextile/ Agg Base | 1d | 2024-10-18 | 2024-10-18 | 306 | 235d | 0d |
| 308 | 2.12.3.8 | Survey and Acceptance | 3d | 2024-10-21 | 2024-10-23 | 307 | 235d | 0d |
| 309 | 2.12.3.9 | Set Forms for Curb | 1d | 2024-10-24 | 2024-10-24 | 308 | 235d | 0d |
| 310 | 2.12.3.10 | Place Curb | 2d | 2024-10-25 | 2024-10-28 | 309 | 235d | 0d |
| 311 | 2.12.3.11 | Cure Curb | 3d | 2024-10-29 | 2024-10-31 | 310 | 235d | 0d |
| 312 | 2.12.3.12 | Paving & Patching | 1d | 2024-11-01 | 2024-11-01 | 311 | 235d | 0d |
| 313 | 2.12.3.13 | Set Back of Walk Form | 1d | 2024-10-31 | 2024-10-31 | 295, 308, 311FS-1d | 236d | 1d |
| 314 | 2.12.3.14 | Place Sidewalk & Ped Ramp | 5d | 2024-11-04 | 2024-11-08 | 312, 313 | 235d | 0d |
| 315 | 2.12.3.15 | Cure Sidewalk & Ped Ramp | 3d | 2024-11-11 | 2024-11-13 | 314 | 235d |  |
| 316 | 2.12.4 | **Sidewalk Along Sidestreets & Intersections TPAR Area** | 65d | 2024-11-14 | 2025-02-12 | 300 | 235d |  |
| 317 | 2.12.4.1 | Place Construction Signing | 1d | 2024-11-14 | 2024-11-14 |  | 235d | 0d |
| 318 | 2.12.4.2 | Construct Another Set of Temp Pedestrian Accessible Routes | 4d | 2024-11-15 | 2024-11-20 | 317 | 235d | 0d |
| 319 | 2.12.4.3 | Shift Traffic to TPAR | 1d | 2024-11-21 | 2024-11-21 | 318 | 235d | 36d |
| 320 | 2.12.4.4 | Saw Cut Existing Shoulder & Pavement Removal | 2d | 2025-01-13 | 2025-01-14 | 319, 28 | 199d | 0d |
| 321 | 2.12.4.5 | Earthwork | 2d | 2025-01-15 | 2025-01-16 | 318, 320 | 199d | 0d |
| 322 | 2.12.4.6 | Place Geotextile/ Agg Base | 1d | 2025-01-17 | 2025-01-17 | 321 | 199d | 0d |
| 323 | 2.12.4.7 | Survey and Acceptance | 3d | 2025-01-20 | 2025-01-22 | 322 | 199d | 0d |
| 324 | 2.12.4.8 | Set Forms for Curb | 1d | 2025-01-23 | 2025-01-23 | 323 | 199d | 0d |
| 325 | 2.12.4.9 | Place Curb | 2d | 2025-01-24 | 2025-01-27 | 324 | 199d | 0d |
| 326 | 2.12.4.10 | Cure Curb | 3d | 2025-01-28 | 2025-01-30 | 325 | 199d | 0d |
| 327 | 2.12.4.11 | Paving & Patching | 1d | 2025-01-31 | 2025-01-31 | 326 | 199d | 0d |
| 328 | 2.12.4.12 | Set Back of Walk Form | 1d | 2025-01-30 | 2025-01-30 | 323, 326FS-1d | 200d | 1d |
| 329 | 2.12.4.13 | Place Sidewalk & Ped Ramp | 5d | 2025-02-03 | 2025-02-07 | 327, 328 | 199d | 0d |
| 330 | 2.12.4.14 | Cure Sidewalk & Ped Ramp | 3d | 2025-02-10 | 2025-02-12 | 329 | 244d |  |

| ID | WBS | Task | Duration | Start | Finish | Predecessors | Total slack | Free slack |
| --- | --- | --- | --- | --- | --- | --- | --- | --- |
| 331 | 2.12.5 | **Sidewalk in Intersection Radii** | 33d | 2025-02-10 | 2025-03-26 | 329 | 199d | 0d |
| 332 | 2.12.5.1 | Place Construction Signing | 1d | 2025-02-10 | 2025-02-10 |  | 199d | 0d |
| 333 | 2.12.5.2 | Construct Another Set of Temp Pedestrian Accessible Routes | 3d | 2025-02-11 | 2025-02-13 | 332 | 199d | 0d |
| 334 | 2.12.5.3 | Shift Traffic to TPAR | 1d | 2025-02-14 | 2025-02-14 | 333 | 199d | 0d |
| 335 | 2.12.5.4 | Saw Cut Existing Shoulder & Pavement Removal | 2d | 2025-02-17 | 2025-02-18 | 334 | 199d | 0d |
| 336 | 2.12.5.5 | Earthwork | 2d | 2025-02-19 | 2025-02-20 | 333, 335 | 199d | 0d |
| 337 | 2.12.5.6 | Place Geotextile/ Agg Base | 1d | 2025-02-21 | 2025-02-21 | 336 | 199d | 0d |
| 338 | 2.12.5.7 | Survey and Acceptance | 3d | 2025-02-24 | 2025-02-26 | 337 | 199d | 0d |
| 339 | 2.12.5.8 | Set Forms for Curb | 1d | 2025-02-27 | 2025-02-27 | 338 | 199d | 0d |
| 340 | 2.12.5.9 | Place Curb | 2d | 2025-02-28 | 2025-03-03 | 339 | 199d | 0d |
| 341 | 2.12.5.10 | Cure Curb | 3d | 2025-03-04 | 2025-03-06 | 340 | 199d | 0d |
| 342 | 2.12.5.11 | Paving & Patching | 1d | 2025-03-07 | 2025-03-07 | 341 | 199d | 0d |
| 343 | 2.12.5.12 | Set Back of Walk Form | 1d | 2025-03-06 | 2025-03-06 | 338, 341FS-1d | 200d | 1d |
| 344 | 2.12.5.13 | Place Sidewalk & Ped Ramp | 5d | 2025-03-10 | 2025-03-14 | 342, 343 | 199d | 0d |
| 345 | 2.12.5.14 | Cure Sidewalk & Ped Ramp | 3d | 2025-03-17 | 2025-03-19 | 344 | 199d | 0d |
| 346 | 2.12.5.15 | Remove TPARs | 2d | 2025-03-20 | 2025-03-21 | 345 | 202d |  |
| 347 | 2.12.5.16 | Site Paving | 5d | 2025-03-20 | 2025-03-26 | 345 | 199d |  |
| 348 | 2.12.6 | 2024 Project Contingency Days (weather) | 15d | 2025-03-27 | 2025-04-16 | 331 | 199d |  |
| 349 | 2.13 | **SE 99th - SE 122th AVE: CONST SOUTH SIDE WIDENING** | 444d | 2024-06-13 | 2026-02-24 |  | 139d |  |
| 350 | 2.13.1 | **Stage 1: Temporary Paving** | 13d | 2024-06-13 | 2024-07-01 |  | 139d | 0d |
| 351 | 2.13.1.1 | Place Construction TCD | 1d | 2024-06-13 | 2024-06-13 | 270FS-24d | 139d | 0d |
| 352 | 2.13.1.2 | Place Erosion Control Measures | 1d | 2024-06-14 | 2024-06-14 | 351 | 150d |  |
| 353 | 2.13.1.3 | Install Temporary Fencing for Tree Protection | 2d | 2024-06-14 | 2024-06-17 | 351 | 139d | 0d |
| 354 | 2.13.1.4 | Saw Cut Existing Shoulder & Pavement Removal | 2d | 2024-06-14 | 2024-06-17 | 351 | 139d | 0d |
| 355 | 2.13.1.5 | Earthwork | 3d | 2024-06-18 | 2024-06-20 | 353, 354 | 139d | 0d |
| 356 | 2.13.1.6 | Place Geotextile/ Agg Base | 1d | 2024-06-21 | 2024-06-21 | 355 | 139d | 0d |
| 357 | 2.13.1.7 | Adjust Water Meters and Existing Inlets to Interim Grades | 3d | 2024-06-24 | 2024-06-26 | 356 | 139d | 0d |
| 358 | 2.13.1.8 | Survey and Acceptance | 3d | 2024-06-24 | 2024-06-26 | 356 | 139d | 0d |
| 359 | 2.13.1.9 | Temporary Paving | 2d | 2024-06-27 | 2024-06-28 | 357, 358 | 139d | 0d |
| 360 | 2.13.1.10 | Shift Traffic | 1d | 2024-07-01 | 2024-07-01 | 359 | 139d |  |

| ID | WBS | Task | Duration | Start | Finish | Predecessors | Total slack | Free slack |
| --- | --- | --- | --- | --- | --- | --- | --- | --- |
| 361 | 2.13.2 | **South Side US-26 Widening** | 312d | 2024-07-02 | 2025-09-10 | 350 | 139d |  |
| 362 | 2.13.2.1 | Place Construction Signing | 1d | 2024-07-02 | 2024-07-02 |  | 139d | 0d |
| 363 | 2.13.2.2 | Remove/ Cover Existing Striping, Install Temporary Striping | 1d | 2024-07-03 | 2024-07-03 | 362 | 139d | 0d |
| 364 | 2.13.2.3 | Place Erosion Control Measures | 1d | 2024-07-04 | 2024-07-04 | 363 | 745d |  |
| 365 | 2.13.2.4 | Saw Cut Existing Shoulder & Pavement Removal | 2d | 2024-07-04 | 2024-07-05 | 363 | 139d | 0d |
| 366 | 2.13.2.5 | First blocks of Earthwork & some very small block retaining walls | 6d | 2024-07-08 | 2024-07-15 | 365 | 139d | 0d |
| 367 | 2.13.2.6 | **Stage 2 Phase 1: Reach 1 of Water Relocation - SE 122nd Ave to SE 116th Ave** | 46d | 2024-07-16 | 2024-09-17 | 366 | 139d |  |
| 368 | 2.13.2.6.1 | water main | 8d | 2024-07-16 | 2024-07-25 |  | 139d | 0d |
| 369 | 2.13.2.6.2 | water service lines | 4d | 2024-07-24 | 2024-07-29 | 368FF+2d | 139d | 0d |
| 370 | 2.13.2.6.3 | hydrants | 3d | 2024-07-26 | 2024-07-30 | 368 | 727d |  |
| 371 | 2.13.2.6.4 | preliminary flushing and pressure testing | 1d | 2024-07-30 | 2024-07-30 | 369 | 139d | 0d |
| 372 | 2.13.2.6.5 | testing readiness notice to PWB | 2d | 2024-07-31 | 2024-08-01 | 371 | 139d | 0d |
| 373 | 2.13.2.6.6 | PWB forces pressure testing | 2d | 2024-08-02 | 2024-08-05 | 372 | 139d | 0d |
| 374 | 2.13.2.6.7 | PWB forces witness & sampling for bacteriological testing | 1d | 2024-08-06 | 2024-08-06 | 373 | 139d | 0d |
| 375 | 2.13.2.6.8 | PWB forces lab testing (1st & 2nd tests) | 2d | 2024-08-07 | 2024-08-08 | 374 | 139d | 0d |
| 376 | 2.13.2.6.9 | meter readiness notice to PWB | 5d | 2024-08-27 | 2024-09-02 | 375, 379FF | 692d | 0d |
| 377 | 2.13.2.6.10 | PWB forces locates | 3d | 2024-08-09 | 2024-08-13 | 375 | 139d | 0d |
| 378 | 2.13.2.6.11 | PWB forces main tie ins (7 connections incl cross streets) | 14d | 2024-08-14 | 2024-09-02 | 377 | 139d | 0d |
| 379 | 2.13.2.6.12 | backside plumbing on service lines | 4d | 2024-08-28 | 2024-09-02 | 378FF, 369 | 692d | 0d |
| 380 | 2.13.2.6.13 | PWB forces water meter installation (12 meters) | 2d | 2024-09-03 | 2024-09-04 | 379, 376 | 692d | 0d |
| 381 | 2.13.2.6.14 | disconnect readiness notice to PWB | 2d | 2024-09-05 | 2024-09-06 | 380 | 692d | 0d |
| 382 | 2.13.2.6.15 | PWB forces disconnection (7 connections incl cross streets) | 7d | 2024-09-09 | 2024-09-17 | 381 | 692d |  |
| 383 | 2.13.2.7 | **Stage 2 Phase 1: Reach 2 of Water Relocation - SE 116th Ave to SE 112th Ave** | 45d | 2024-09-05 | 2024-11-06 | 378FS+2d | 139d |  |
| 384 | 2.13.2.7.1 | water main | 7d | 2024-09-05 | 2024-09-13 |  | 139d | 0d |
| 385 | 2.13.2.7.2 | water service lines | 6d | 2024-09-10 | 2024-09-17 | 384FF+2d | 139d | 0d |
| 386 | 2.13.2.7.3 | hydrants | 1d | 2024-09-16 | 2024-09-16 | 384 | 693d |  |
| 387 | 2.13.2.7.4 | preliminary flushing and pressure testing | 1d | 2024-09-18 | 2024-09-18 | 385 | 139d | 0d |
| 388 | 2.13.2.7.5 | testing readiness notice to PWB | 2d | 2024-09-19 | 2024-09-20 | 387 | 139d | 0d |
| 389 | 2.13.2.7.6 | PWB forces pressure testing | 2d | 2024-09-23 | 2024-09-24 | 388 | 139d | 0d |
| 390 | 2.13.2.7.7 | PWB forces witness & sampling for bacteriological testing | 1d | 2024-09-25 | 2024-09-25 | 389 | 139d | 0d |
| 391 | 2.13.2.7.8 | PWB forces lab testing (1st & 2nd tests) | 2d | 2024-09-26 | 2024-09-27 | 390 | 139d | 0d |
| 392 | 2.13.2.7.9 | meter readiness notice to PWB | 5d | 2024-10-16 | 2024-10-22 | 391, 395FF | 656d | 0d |
| 393 | 2.13.2.7.10 | PWB forces locates | 3d | 2024-09-30 | 2024-10-02 | 391 | 139d | 0d |
| 394 | 2.13.2.7.11 | PWB forces main tie ins (7 connections incl cross streets) | 14d | 2024-10-03 | 2024-10-22 | 393 | 139d | 0d |
| 395 | 2.13.2.7.12 | backside plumbing on service lines | 4d | 2024-10-17 | 2024-10-22 | 394FF, 385 | 656d | 0d |
| 396 | 2.13.2.7.13 | PWB forces Water Meter Installation (17 meters) | 2d | 2024-10-23 | 2024-10-24 | 395, 392 | 656d | 0d |
| 397 | 2.13.2.7.14 | disconnect readiness notice to PWB | 2d | 2024-10-25 | 2024-10-28 | 396 | 656d | 0d |
| 398 | 2.13.2.7.15 | PWB forces disconnection (7 connections incl cross streets) | 7d | 2024-10-29 | 2024-11-06 | 397 | 656d |  |

| ID | WBS | Task | Duration | Start | Finish | Predecessors | Total slack | Free slack |
| --- | --- | --- | --- | --- | --- | --- | --- | --- |
| 399 | 2.13.2.8 | **Stage 2 Phase 1: Reach 3 of Water Relocation - SE 112th Ave to SE 108th Ave** | 78d | 2024-10-25 | 2025-02-11 | 394FS+2d | 139d |  |
| 400 | 2.13.2.8.1 | water main | 8d | 2024-10-25 | 2024-11-05 |  | 139d | 0d |
| 401 | 2.13.2.8.2 | water service lines | 5d | 2024-11-01 | 2024-11-07 | 400FF+2d | 139d | 0d |
| 402 | 2.13.2.8.3 | hydrants | 1d | 2024-11-06 | 2024-11-06 | 400 | 656d |  |
| 403 | 2.13.2.8.4 | preliminary flushing and pressure testing | 1d | 2024-11-08 | 2024-11-08 | 401 | 139d | 0d |
| 404 | 2.13.2.8.5 | testing readiness notice to PWB | 2d | 2024-11-11 | 2024-11-12 | 403 | 139d | 0d |
| 405 | 2.13.2.8.6 | PWB forces pressure testing | 2d | 2024-11-13 | 2024-11-14 | 404 | 139d | 0d |
| 406 | 2.13.2.8.7 | PWB forces witness & sampling for bacteriological testing | 1d | 2024-11-15 | 2024-11-15 | 405 | 139d | 0d |
| 407 | 2.13.2.8.8 | PWB forces lab testing (1st & 2nd tests) | 2d | 2024-11-18 | 2024-11-19 | 406 | 139d | 0d |
| 408 | 2.13.2.8.9 | meter readiness notice to PWB | 5d | 2024-11-20 | 2024-11-26 | 407 | 633d | 46d |
| 409 | 2.13.2.8.10 | PWB forces locates | 3d | 2025-01-13 | 2025-01-15 | 407, 28 | 101d | 0d |
| 410 | 2.13.2.8.11 | PWB forces main tie ins (5 connections incl cross streets) | 10d | 2025-01-16 | 2025-01-29 | 409 | 101d | 0d |
| 411 | 2.13.2.8.12 | backside plumbing on service lines | 4d | 2025-01-24 | 2025-01-29 | 410FF, 401 | 587d | 0d |
| 412 | 2.13.2.8.13 | PWB Forces Water Meter Installation (15 meters) | 2d | 2025-01-30 | 2025-01-31 | 411, 408 | 587d | 0d |
| 413 | 2.13.2.8.14 | disconnect readiness notice to PWB | 2d | 2025-02-03 | 2025-02-04 | 412 | 587d | 0d |
| 414 | 2.13.2.8.15 | PWB forces disconnection (5 connections incl cross streets) | 5d | 2025-02-05 | 2025-02-11 | 413 | 587d |  |
| 415 | 2.13.2.9 | **Stage 2 Phase 1: Reach 4 of Water Relocation - SE 108th Ave to SE 104th Ave** | 34d | 2025-02-03 | 2025-03-20 | 410FS+2d | 101d |  |
| 416 | 2.13.2.9.1 | water main | 6d | 2025-02-03 | 2025-02-10 |  | 101d | 0d |
| 417 | 2.13.2.9.2 | water service lines | 2d | 2025-02-11 | 2025-02-12 | 416FF+2d | 101d | 0d |
| 418 | 2.13.2.9.3 | hydrants | 1d | 2025-02-11 | 2025-02-11 | 416 | 587d |  |
| 419 | 2.13.2.9.4 | preliminary flushing and pressure testing | 1d | 2025-02-13 | 2025-02-13 | 417 | 101d | 0d |
| 420 | 2.13.2.9.5 | testing readiness notice to PWB | 2d | 2025-02-14 | 2025-02-17 | 419 | 101d | 0d |
| 421 | 2.13.2.9.6 | PWB forces pressure testing | 2d | 2025-02-18 | 2025-02-19 | 420 | 101d | 0d |
| 422 | 2.13.2.9.7 | PWB forces witness & sampling for bacteriological testing | 1d | 2025-02-20 | 2025-02-20 | 421 | 101d | 0d |
| 423 | 2.13.2.9.8 | PWB forces lab testing (1st & 2nd tests) | 2d | 2025-02-21 | 2025-02-24 | 422 | 101d | 0d |
| 424 | 2.13.2.9.9 | meter readiness notice to PWB | 5d | 2025-02-25 | 2025-03-03 | 423 | 566d | 6d |
| 425 | 2.13.2.9.10 | PWB forces locates | 3d | 2025-02-25 | 2025-02-27 | 423 | 101d | 0d |
| 426 | 2.13.2.9.11 | PWB forces main tie ins (4 connections incl cross streets) | 8d | 2025-02-28 | 2025-03-11 | 425 | 101d | 0d |
| 427 | 2.13.2.9.12 | backside plumbing on service lines | 2d | 2025-03-10 | 2025-03-11 | 426FF, 417 | 560d | 0d |
| 428 | 2.13.2.9.13 | PWB Forces Water Meter Installation (5 meters) | 1d | 2025-03-12 | 2025-03-12 | 427, 424 | 560d | 0d |
| 429 | 2.13.2.9.14 | disconnect readiness notice to PWB | 2d | 2025-03-13 | 2025-03-14 | 428 | 560d | 0d |
| 430 | 2.13.2.9.15 | PWB forces disconnection (4 connections incl cross streets) | 4d | 2025-03-17 | 2025-03-20 | 429 | 560d |  |

| ID | WBS | Task | Duration | Start | Finish | Predecessors | Total slack | Free slack |
| --- | --- | --- | --- | --- | --- | --- | --- | --- |
| 431 | 2.13.2.10 | **Stage 2 Phase 1: Reach 5 of Water Relocation - SE 104th Ave through Ed Benedict Park** | 40d | 2025-03-14 | 2025-05-08 | 426FS+2d | 101d |  |
| 432 | 2.13.2.10.1 | water main | 6d | 2025-03-14 | 2025-03-21 |  | 101d | 0d |
| 433 | 2.13.2.10.2 | water service lines | 3d | 2025-03-21 | 2025-03-25 | 432FF+2d | 101d | 0d |
| 434 | 2.13.2.10.3 | hydrants | 1d | 2025-03-24 | 2025-03-24 | 432 | 558d |  |
| 435 | 2.13.2.10.4 | preliminary flushing and pressure testing | 1d | 2025-03-26 | 2025-03-26 | 433 | 101d | 0d |
| 436 | 2.13.2.10.5 | testing readiness notice to PWB | 2d | 2025-03-27 | 2025-03-28 | 435 | 101d | 0d |
| 437 | 2.13.2.10.6 | PWB forces pressure testing | 2d | 2025-03-31 | 2025-04-01 | 436 | 101d | 0d |
| 438 | 2.13.2.10.7 | PWB forces witness & sampling for bacteriological testing | 1d | 2025-04-02 | 2025-04-02 | 437 | 101d | 0d |
| 439 | 2.13.2.10.8 | PWB forces lab testing (1st & 2nd tests) | 2d | 2025-04-03 | 2025-04-04 | 438 | 101d | 0d |
| 440 | 2.13.2.10.9 | meter readiness notice to PWB | 5d | 2025-04-07 | 2025-04-11 | 439 | 109d | 8d |
| 441 | 2.13.2.10.10 | PWB forces locates | 3d | 2025-04-07 | 2025-04-09 | 439 | 101d | 0d |
| 442 | 2.13.2.10.11 | PWB forces main tie ins (5 connections incl cross streets) | 10d | 2025-04-10 | 2025-04-23 | 441 | 101d | 0d |
| 443 | 2.13.2.10.12 | backside plumbing on service lines | 3d | 2025-04-21 | 2025-04-23 | 442FF, 433 | 101d | 0d |
| 444 | 2.13.2.10.13 | PWB Forces Water Meter Installation (8 meters) | 1d | 2025-04-24 | 2025-04-24 | 443, 440 | 101d | 0d |
| 445 | 2.13.2.10.14 | disconnect readiness notice to PWB | 2d | 2025-04-25 | 2025-04-28 | 444 | 101d | 0d |
| 446 | 2.13.2.10.15 | PWB forces disconnection (5 connections incl cross streets) | 5d | 2025-04-29 | 2025-05-05 | 445 | 101d | 0d |
| 447 | 2.13.2.10.16 | PWB forces meter box relocation around SE 99th Ave (6 meters) | 3d | 2025-05-06 | 2025-05-08 | 446 | 525d |  |
| 448 | 2.13.2.11 | Stage 2 Phase 2: Install Drywells and Sediment MHs from 99th Ave to 112th Ave | 45d | 2025-03-11 | 2025-05-12 | 446FF+5d | 101d | 0d |
| 449 | 2.13.2.12 | Stage 2 Phase 2: Install Storm Sewer Pipe and MHs from 99th Ave to 112th Ave | 20d | 2025-04-22 | 2025-05-19 | 448FF+5d | 101d | 0d |
| 450 | 2.13.2.13 | Finish Placing South Side Geotextile/ Agg Base | 1d | 2025-05-20 | 2025-05-20 | 449 | 113d | 0d |
| 451 | 2.13.2.14 | Stage 2 Phase 2: Install Storm Inlets | 20d | 2025-05-20 | 2025-06-16 | 449 | 101d | 0d |
| 452 | 2.13.2.15 | Stage 3 Phase 2: Set Forms & Stringline for Curb & Concrete Pavement | 2d | 2025-06-17 | 2025-06-18 | 451 | 101d | 0d |
| 453 | 2.13.2.16 | Stage 3 Phase 2: Place First Blocks of Curb & Bus Stop Concrete Pavement | 6d | 2025-06-19 | 2025-06-26 | 452 | 101d | 0d |
| 454 | 2.13.2.17 | Stage 3 Phase 2: Cure Curb & Bus Stop Concrete Pavement | 5d | 2025-06-27 | 2025-07-03 | 453 | 101d | 0d |
| 455 | 2.13.2.18 | Stage 3 Phase 2: Paving & Patching | 1d | 2025-07-04 | 2025-07-04 | 454 | 484d |  |
| 456 | 2.13.2.19 | Stage 3 Phase 2: Install Signal & Light Pole Foundations & Conduit | 20d | 2025-05-21 | 2025-06-17 | 294, 450 | 113d | 12d |
| 457 | 2.13.2.20 | Stage 3 Phase 1: Install Temporary Signals | 60d | 2024-07-02 | 2024-09-23 | 166 | 391d | 290d |
| 458 | 2.13.2.21 | Stage 3 Phase 2: Set Back of Walk Form | 1d | 2025-07-04 | 2025-07-04 | 456, 454 | 101d | 0d |
| 459 | 2.13.2.22 | Stage 3 Phase 2: Place Sidewalk & Driveways | 40d | 2025-07-07 | 2025-08-29 | 458 | 101d | 0d |
| 460 | 2.13.2.23 | Stage 3 Phase 2: Cure Sidewalk & Driveways | 3d | 2025-09-01 | 2025-09-03 | 459 | 436d | 0d |
| 461 | 2.13.2.24 | Stage 3 Phase 2: Complete Planter Strips | 5d | 2025-09-04 | 2025-09-10 | 460 | 436d |  |
| 462 | 2.13.2.25 | Stage 3 Phase 2: Driveway Paving | 5d | 2025-09-04 | 2025-09-10 | 460 | 436d |  |

| ID | WBS | Task | Duration | Start | Finish | Predecessors | Total slack | Free slack |
| --- | --- | --- | --- | --- | --- | --- | --- | --- |
| 463 | 2.13.3 | **Sidewalk Along US-26 at Intersections** | 30d | 2025-08-18 | 2025-09-26 |  | 101d | 0d |
| 464 | 2.13.3.1 | Place Construction Signing | 1d | 2025-08-18 | 2025-08-18 | 459FS-10d | 101d | 0d |
| 465 | 2.13.3.2 | Place Erosion Control Measures | 1d | 2025-08-19 | 2025-08-19 | 464 | 101d | 0d |
| 466 | 2.13.3.3 | Construct Temp Pedestrian Accessible Routes | 4d | 2025-08-20 | 2025-08-25 | 465 | 101d | 0d |
| 467 | 2.13.3.4 | Shift Traffic to TPAR | 1d | 2025-08-26 | 2025-08-26 | 466 | 101d | 0d |
| 468 | 2.13.3.5 | Saw Cut Existing Shoulder & Pavement Removal | 2d | 2025-08-27 | 2025-08-28 | 467 | 101d | 0d |
| 469 | 2.13.3.6 | Earthwork | 2d | 2025-08-29 | 2025-09-01 | 466, 468 | 101d | 0d |
| 470 | 2.13.3.7 | Place Geotextile/ Agg Base | 1d | 2025-09-02 | 2025-09-02 | 469 | 101d | 0d |
| 471 | 2.13.3.8 | Survey and Acceptance | 3d | 2025-09-03 | 2025-09-05 | 470 | 101d | 0d |
| 472 | 2.13.3.9 | Set Forms for Curb | 1d | 2025-09-08 | 2025-09-08 | 471 | 101d | 0d |
| 473 | 2.13.3.10 | Place Curb | 2d | 2025-09-09 | 2025-09-10 | 472 | 101d | 0d |
| 474 | 2.13.3.11 | Cure Curb | 3d | 2025-09-11 | 2025-09-15 | 473 | 101d | 0d |
| 475 | 2.13.3.12 | Paving & Patching | 1d | 2025-09-16 | 2025-09-16 | 474 | 101d | 0d |
| 476 | 2.13.3.13 | Set Back of Walk Form | 1d | 2025-09-15 | 2025-09-15 | 471, 474FS-1d, 458 | 102d | 1d |
| 477 | 2.13.3.14 | Place Sidewalk & Ped Ramp | 5d | 2025-09-17 | 2025-09-23 | 475, 476 | 101d | 0d |
| 478 | 2.13.3.15 | Cure Sidewalk & Ped Ramp | 3d | 2025-09-24 | 2025-09-26 | 477 | 101d |  |
| 479 | 2.13.4 | **Sidewalk Along Sidestreets & Intersections TPAR Area** | 29d | 2025-09-29 | 2025-11-06 | 463 | 101d |  |
| 480 | 2.13.4.1 | Place Construction Signing | 1d | 2025-09-29 | 2025-09-29 |  | 101d | 0d |
| 481 | 2.13.4.2 | Construct Another Set of Temp Pedestrian Accessible Routes | 4d | 2025-09-30 | 2025-10-03 | 480 | 101d | 0d |
| 482 | 2.13.4.3 | Shift Traffic to TPAR | 1d | 2025-10-06 | 2025-10-06 | 481 | 101d | 0d |
| 483 | 2.13.4.4 | Saw Cut Existing Shoulder & Pavement Removal | 2d | 2025-10-07 | 2025-10-08 | 482 | 101d | 0d |
| 484 | 2.13.4.5 | Earthwork | 2d | 2025-10-09 | 2025-10-10 | 481, 483 | 101d | 0d |
| 485 | 2.13.4.6 | Place Geotextile/ Agg Base | 1d | 2025-10-13 | 2025-10-13 | 484 | 101d | 0d |
| 486 | 2.13.4.7 | Survey and Acceptance | 3d | 2025-10-14 | 2025-10-16 | 485 | 101d | 0d |
| 487 | 2.13.4.8 | Set Forms for Curb | 1d | 2025-10-17 | 2025-10-17 | 486 | 101d | 0d |
| 488 | 2.13.4.9 | Place Curb | 2d | 2025-10-20 | 2025-10-21 | 487 | 101d | 0d |
| 489 | 2.13.4.10 | Cure Curb | 3d | 2025-10-22 | 2025-10-24 | 488 | 101d | 0d |
| 490 | 2.13.4.11 | Paving & Patching | 1d | 2025-10-27 | 2025-10-27 | 489 | 101d | 0d |
| 491 | 2.13.4.12 | Set Back of Walk Form | 1d | 2025-10-24 | 2025-10-24 | 486, 489FS-1d | 102d | 1d |
| 492 | 2.13.4.13 | Place Sidewalk & Ped Ramp | 5d | 2025-10-28 | 2025-11-03 | 490, 491 | 101d | 0d |
| 493 | 2.13.4.14 | Cure Sidewalk & Ped Ramp | 3d | 2025-11-04 | 2025-11-06 | 492 | 395d |  |

| ID | WBS | Task | Duration | Start | Finish | Predecessors | Total slack | Free slack |
| --- | --- | --- | --- | --- | --- | --- | --- | --- |
| 494 | 2.13.5 | **Sidewalk in Intersection Radii** | 66d | 2025-11-04 | 2026-02-03 | 492 | 65d | 0d |
| 495 | 2.13.5.1 | Place Construction Signing | 1d | 2025-11-04 | 2025-11-04 | 457 | 101d | 0d |
| 496 | 2.13.5.2 | Construct Another Set of Temp Pedestrian Accessible Routes | 3d | 2025-11-05 | 2025-11-07 | 495 | 101d | 0d |
| 497 | 2.13.5.3 | Shift Traffic to TPAR | 1d | 2025-11-10 | 2025-11-10 | 496 | 101d | 0d |
| 498 | 2.13.5.4 | Saw Cut Existing Shoulder & Pavement Removal | 2d | 2025-11-11 | 2025-11-12 | 497 | 101d | 0d |
| 499 | 2.13.5.5 | Earthwork | 2d | 2025-11-13 | 2025-11-14 | 496, 498 | 101d | 0d |
| 500 | 2.13.5.6 | Place Geotextile/ Agg Base | 1d | 2025-11-17 | 2025-11-17 | 499 | 101d | 0d |
| 501 | 2.13.5.7 | Survey and Acceptance | 3d | 2025-11-18 | 2025-11-20 | 500 | 101d | 36d |
| 502 | 2.13.5.8 | Set Forms for Curb | 1d | 2026-01-12 | 2026-01-12 | 501, 29 | 65d | 0d |
| 503 | 2.13.5.9 | Place Curb | 2d | 2026-01-13 | 2026-01-14 | 502 | 65d | 0d |
| 504 | 2.13.5.10 | Cure Curb | 3d | 2026-01-15 | 2026-01-19 | 503 | 65d | 0d |
| 505 | 2.13.5.11 | Paving & Patching | 1d | 2026-01-20 | 2026-01-20 | 504 | 65d | 0d |
| 506 | 2.13.5.12 | Set Back of Walk Form | 1d | 2026-01-19 | 2026-01-19 | 501, 504FS-1d | 66d | 1d |
| 507 | 2.13.5.13 | Place Sidewalk & Ped Ramp | 5d | 2026-01-21 | 2026-01-27 | 505, 506 | 65d | 0d |
| 508 | 2.13.5.14 | Cure Sidewalk & Ped Ramp | 3d | 2026-01-28 | 2026-01-30 | 507 | 65d | 0d |
| 509 | 2.13.5.15 | Remove TPARs | 2d | 2026-02-02 | 2026-02-03 | 508 | 65d |  |
| 510 | 2.13.6 | 2025 Project Contingency Days (weather) | 15d | 2026-02-04 | 2026-02-24 | 494 | 65d | 0d |
| 511 | 2.14 | **SE 136th - ECL: CONST NORTH SIDE WIDENING** | 332d | 2025-04-17 | 2026-07-24 |  | 161d | 0d |
| 512 | 2.14.1 | **North Side US-26 Widening** | 249d | 2025-04-17 | 2026-03-31 | 35, 220 | 199d |  |
| 513 | 2.14.1.1 | Place Construction Signing | 1d | 2025-04-17 | 2025-04-17 |  | 199d | 0d |
| 514 | 2.14.1.2 | Remove/ Cover Existing Striping, Install Temporary Striping | 1d | 2025-04-18 | 2025-04-18 | 513 | 199d | 0d |
| 515 | 2.14.1.3 | Place Erosion Control Measures | 1d | 2025-04-21 | 2025-04-21 | 514 | 199d | 0d |
| 516 | 2.14.1.4 | Saw Cut Existing Shoulder & Pavement Removal | 2d | 2025-04-21 | 2025-04-22 | 514 | 229d | 0d |
| 517 | 2.14.1.5 | First Blocks of Earthwork | 4d | 2025-04-23 | 2025-04-28 | 516 | 229d | 30d |
| 518 | 2.14.1.6 | Stage 3 Phase 2: Install North Side and Some South Side Drywells and Sediment MHs | 45d | 2025-04-22 | 2025-06-23 | 515 | 199d | 0d |
| 519 | 2.14.1.7 | Stage 3 Phase 2: Install North Side Storm Sewer Pipe and MHs | 23d | 2025-06-10 | 2025-07-10 | 517, 518FS-10d | 199d | 0d |
| 520 | 2.14.1.8 | Finish Placing North Side Geotextile/ Agg Base | 1d | 2025-07-11 | 2025-07-11 | 519 | 230d | 0d |
| 521 | 2.14.1.9 | Stage 3 Phase 2: Install Storm Inlets | 40d | 2025-07-11 | 2025-09-04 | 519 | 199d | 0d |
| 522 | 2.14.1.10 | Stage 3 Phase 3: Set Forms for Curb & Concrete Pavement | 1d | 2025-09-05 | 2025-09-05 | 521 | 199d | 0d |
| 523 | 2.14.1.11 | Stage 3 Phase 3: Place First Blocks of Curb & Bus Stop Concrete Pavement | 6d | 2025-09-08 | 2025-09-15 | 522 | 199d | 0d |
| 524 | 2.14.1.12 | Stage 3 Phase 3: Cure Curb & Bus Stop Concrete Pavement | 5d | 2025-09-16 | 2025-09-22 | 523 | 199d | 0d |
| 525 | 2.14.1.13 | Stage 3 Phase 3: Paving & Patching | 1d | 2025-09-23 | 2025-09-23 | 524 | 379d |  |
| 526 | 2.14.1.14 | Stage 3 Phase 3: Install Signal & Light Pole Foundations & Conduit | 20d | 2025-07-14 | 2025-08-08 | 520, 456 | 230d | 31d |
| 527 | 2.14.1.15 | Stage 3 Phase 1: Install Temporary Signals | 60d | 2025-04-17 | 2025-07-09 | 166 | 382d | 225d |
| 528 | 2.14.1.16 | Stage 3 Phase 3: Set Back of Walk Form | 1d | 2025-09-23 | 2025-09-23 | 526, 524 | 199d | 0d |
| 529 | 2.14.1.17 | Stage 3 Phase 3: Place Sidewalk & Driveways | 36d | 2025-09-24 | 2025-11-12 | 528 | 199d | 42d |
| 530 | 2.14.1.18 | Stage 3 Phase 3: Place Sidewalk & Driveways | 44d | 2026-01-12 | 2026-03-12 | 529, 29 | 157d | 0d |
| 531 | 2.14.1.19 | Stage 3 Phase 3: Cure Sidewalk & Driveways | 3d | 2026-03-13 | 2026-03-17 | 529, 530 | 244d | 0d |
| 532 | 2.14.1.20 | Stage 3 Phase 3: Complete Planter Strips | 10d | 2026-03-18 | 2026-03-31 | 531 | 244d |  |
| 533 | 2.14.1.21 | Stage 3 Phase 3: Driveway & Site Paving | 10d | 2026-03-18 | 2026-03-31 | 531 | 244d |  |

| ID | WBS | Task | Duration | Start | Finish | Predecessors | Total slack | Free slack |
| --- | --- | --- | --- | --- | --- | --- | --- | --- |
| 534 | 2.14.2 | **Sidewalk Along US-26 at Intersections** | 30d | 2026-02-27 | 2026-04-09 |  | 157d | 0d |
| 535 | 2.14.2.1 | Place Construction Signing | 1d | 2026-02-27 | 2026-02-27 | 529FS-10d, 530FS-10d | 157d | 0d |
| 536 | 2.14.2.2 | Place Erosion Control Measures | 1d | 2026-03-02 | 2026-03-02 | 535 | 157d | 0d |
| 537 | 2.14.2.3 | Construct Temp Pedestrian Accessible Routes | 4d | 2026-03-03 | 2026-03-06 | 536 | 157d | 0d |
| 538 | 2.14.2.4 | Shift Traffic to TPAR | 1d | 2026-03-09 | 2026-03-09 | 537, 524, 529SS+25d, 530SS+25d | 157d | 0d |
| 539 | 2.14.2.5 | Saw Cut Existing Shoulder & Pavement Removal | 2d | 2026-03-10 | 2026-03-11 | 538 | 157d | 0d |
| 540 | 2.14.2.6 | Earthwork | 2d | 2026-03-12 | 2026-03-13 | 537, 539 | 157d | 0d |
| 541 | 2.14.2.7 | Place Geotextile/ Agg Base | 1d | 2026-03-16 | 2026-03-16 | 540 | 157d | 0d |
| 542 | 2.14.2.8 | Survey and Acceptance | 3d | 2026-03-17 | 2026-03-19 | 541 | 157d | 0d |
| 543 | 2.14.2.9 | Set Forms for Curb | 1d | 2026-03-20 | 2026-03-20 | 542 | 157d | 0d |
| 544 | 2.14.2.10 | Place Curb | 2d | 2026-03-23 | 2026-03-24 | 543 | 157d | 0d |
| 545 | 2.14.2.11 | Cure Curb | 3d | 2026-03-25 | 2026-03-27 | 544 | 157d | 0d |
| 546 | 2.14.2.12 | Paving & Patching | 1d | 2026-03-30 | 2026-03-30 | 545 | 157d | 0d |
| 547 | 2.14.2.13 | Set Back of Walk Form | 1d | 2026-03-27 | 2026-03-27 | 542, 545FS-1d, 528 | 158d | 1d |
| 548 | 2.14.2.14 | Place Sidewalk & Ped Ramp | 5d | 2026-03-31 | 2026-04-06 | 546, 547 | 157d | 0d |
| 549 | 2.14.2.15 | Cure Sidewalk & Ped Ramp | 3d | 2026-04-07 | 2026-04-09 | 548 | 157d |  |
| 550 | 2.14.3 | **Sidewalk Along Sidestreets & Intersections TPAR Area** | 32d | 2026-04-10 | 2026-05-25 | 534 | 157d |  |
| 551 | 2.14.3.1 | Place Construction Signing | 1d | 2026-04-10 | 2026-04-10 |  | 157d | 0d |
| 552 | 2.14.3.2 | Construct Another Set of Temp Pedestrian Accessible Routes | 4d | 2026-04-13 | 2026-04-16 | 551 | 157d | 0d |
| 553 | 2.14.3.3 | Shift Traffic to TPAR | 1d | 2026-04-17 | 2026-04-17 | 552 | 157d | 0d |
| 554 | 2.14.3.4 | Saw Cut Existing Shoulder & Pavement Removal | 2d | 2026-04-20 | 2026-04-21 | 553 | 157d | 0d |
| 555 | 2.14.3.5 | Earthwork | 2d | 2026-04-22 | 2026-04-23 | 552, 554 | 157d | 0d |
| 556 | 2.14.3.6 | Place Geotextile/ Agg Base | 1d | 2026-04-24 | 2026-04-24 | 555 | 157d | 0d |
| 557 | 2.14.3.7 | Survey and Acceptance | 3d | 2026-04-27 | 2026-04-29 | 556 | 157d | 0d |
| 558 | 2.14.3.8 | Set Forms for Curb | 1d | 2026-04-30 | 2026-04-30 | 557 | 157d | 0d |
| 559 | 2.14.3.9 | Place Curb | 3d | 2026-05-01 | 2026-05-05 | 558 | 157d | 0d |
| 560 | 2.14.3.10 | Cure Curb | 3d | 2026-05-06 | 2026-05-08 | 559 | 157d | 0d |
| 561 | 2.14.3.11 | Paving & Patching | 1d | 2026-05-11 | 2026-05-11 | 560 | 157d | 0d |
| 562 | 2.14.3.12 | Set Back of Walk Form | 2d | 2026-05-08 | 2026-05-11 | 557, 560FS-1d | 157d | 0d |
| 563 | 2.14.3.13 | Place Sidewalk & Ped Ramp | 7d | 2026-05-12 | 2026-05-20 | 561, 562 | 157d | 0d |
| 564 | 2.14.3.14 | Cure Sidewalk & Ped Ramp | 3d | 2026-05-21 | 2026-05-25 | 563 | 205d |  |

| ID | WBS | Task | Duration | Start | Finish | Predecessors | Total slack | Free slack |
| --- | --- | --- | --- | --- | --- | --- | --- | --- |
| 565 | 2.14.4 | **Sidewalk in Intersection Radii** | 32d | 2026-05-21 | 2026-07-03 | 563 | 157d | 0d |
| 566 | 2.14.4.1 | Place Construction Signing | 1d | 2026-05-21 | 2026-05-21 | 527 | 157d | 0d |
| 567 | 2.14.4.2 | Construct Another Set of Temp Pedestrian Accessible Routes | 3d | 2026-05-22 | 2026-05-26 | 566 | 157d | 0d |
| 568 | 2.14.4.3 | Shift Traffic to TPAR | 1d | 2026-05-27 | 2026-05-27 | 567 | 157d | 0d |
| 569 | 2.14.4.4 | Saw Cut Existing Shoulder & Pavement Removal | 2d | 2026-05-28 | 2026-05-29 | 568 | 157d | 0d |
| 570 | 2.14.4.5 | Earthwork | 2d | 2026-06-01 | 2026-06-02 | 567, 569 | 157d | 0d |
| 571 | 2.14.4.6 | Place Geotextile/ Agg Base | 1d | 2026-06-03 | 2026-06-03 | 570 | 157d | 0d |
| 572 | 2.14.4.7 | Survey and Acceptance | 3d | 2026-06-04 | 2026-06-08 | 571 | 157d | 0d |
| 573 | 2.14.4.8 | Set Forms for Curb | 1d | 2026-06-09 | 2026-06-09 | 572 | 157d | 0d |
| 574 | 2.14.4.9 | Place Curb | 2d | 2026-06-10 | 2026-06-11 | 573 | 157d | 0d |
| 575 | 2.14.4.10 | Cure Curb | 3d | 2026-06-12 | 2026-06-16 | 574 | 157d | 0d |
| 576 | 2.14.4.11 | Paving & Patching | 1d | 2026-06-17 | 2026-06-17 | 575 | 157d | 0d |
| 577 | 2.14.4.12 | Set Back of Walk Form | 1d | 2026-06-16 | 2026-06-16 | 572, 575FS-1d | 158d | 1d |
| 578 | 2.14.4.13 | Place Sidewalk & Ped Ramp | 7d | 2026-06-18 | 2026-06-26 | 576, 577 | 157d | 0d |
| 579 | 2.14.4.14 | Cure Sidewalk & Ped Ramp | 3d | 2026-06-29 | 2026-07-01 | 578 | 157d | 0d |
| 580 | 2.14.4.15 | Remove TPARs | 2d | 2026-07-02 | 2026-07-03 | 579 | 157d |  |
| 581 | 2.14.5 | 2026 Project Contingency Days (weather) | 15d | 2026-07-06 | 2026-07-24 | 565 | 157d | 121d |
| 582 | 2.15 | **SE 99th - SE 122th AVENUE: CONST NORTH SIDE WIDENING** | 200d | 2026-02-25 | 2026-12-01 |  | 65d | 29d |
| 583 | 2.15.1 | **North Side US-26 Widening** | 107d | 2026-02-25 | 2026-07-23 | 510, 29 | 65d |  |
| 584 | 2.15.1.1 | Place Construction Signing | 1d | 2026-02-25 | 2026-02-25 |  | 65d | 0d |
| 585 | 2.15.1.2 | Remove/ Cover Existing Striping, Install Temporary Striping | 1d | 2026-02-26 | 2026-02-26 | 584 | 65d | 0d |
| 586 | 2.15.1.3 | Place Erosion Control Measures | 1d | 2026-02-27 | 2026-02-27 | 585 | 65d | 0d |
| 587 | 2.15.1.4 | Saw Cut Existing Shoulder & Pavement Removal | 2d | 2026-02-27 | 2026-03-02 | 585 | 72d | 0d |
| 588 | 2.15.1.5 | First Blocks of Earthwork | 4d | 2026-03-03 | 2026-03-06 | 587 | 72d | 0d |
| 589 | 2.15.1.6 | Stage 3 Phase 2: Complete the Rest of the Drywells and Sediment MHs from 112th to 122nd | 15d | 2026-03-02 | 2026-03-20 | 586 | 65d | 0d |
| 590 | 2.15.1.7 | Stage 3 Phase 2: Install Rest of Storm Sewer Pipe and MHs from 112th to 122nd | 10d | 2026-03-18 | 2026-03-31 | 588, 589FS-3d | 65d | 0d |
| 591 | 2.15.1.8 | Adjust or Relocate Water Meters and Boxes (PWB) | 6d | 2026-03-09 | 2026-03-16 | 588 | 251d |  |
| 592 | 2.15.1.9 | Finish Placing North Side Geotextile/ Agg Base | 1d | 2026-04-01 | 2026-04-01 | 590 | 239d |  |
| 593 | 2.15.1.10 | Stage 3 Phase 2: Install Storm Inlets | 20d | 2026-04-01 | 2026-04-28 | 590 | 65d | 0d |
| 594 | 2.15.1.11 | Stage 3 Phase 3: Set Forms for Curb & Stringline & Concrete Pavement | 2d | 2026-04-29 | 2026-04-30 | 593 | 65d | 0d |
| 595 | 2.15.1.12 | Stage 3 Phase 3: Place First Blocks of Curb & Bus Stop Concrete Pavement | 6d | 2026-05-01 | 2026-05-08 | 594 | 65d | 0d |
| 596 | 2.15.1.13 | Stage 3 Phase 3: Cure Curb & Bus Stop Concrete Pavement | 5d | 2026-05-11 | 2026-05-15 | 595 | 65d | 0d |
| 597 | 2.15.1.14 | Stage 3 Phase 3: Paving & Patching | 1d | 2026-05-18 | 2026-05-18 | 596 | 206d |  |
| 598 | 2.15.1.15 | Stage 3 Phase 3: Install Signal & Light Pole Foundations & Conduit | 20d | 2026-02-25 | 2026-03-24 |  | 103d | 38d |
| 599 | 2.15.1.16 | Stage 3 Phase 3: Set Back of Walk Form | 1d | 2026-05-18 | 2026-05-18 | 598, 596 | 65d | 0d |
| 600 | 2.15.1.17 | Stage 3 Phase 3: Place Sidewalk & Driveways | 40d | 2026-05-19 | 2026-07-13 | 599 | 65d | 0d |
| 601 | 2.15.1.18 | Stage 3 Phase 3: Cure Sidewalk & Driveways | 3d | 2026-07-14 | 2026-07-16 | 600 | 91d | 0d |
| 602 | 2.15.1.19 | Stage 3 Phase 3: Complete Planter Strips | 5d | 2026-07-17 | 2026-07-23 | 601 | 158d |  |
| 603 | 2.15.1.20 | Stage 3 Phase 3: Driveway Paving | 5d | 2026-07-17 | 2026-07-23 | 601 | 158d |  |

| ID | WBS | Task | Duration | Start | Finish | Predecessors | Total slack | Free slack |
| --- | --- | --- | --- | --- | --- | --- | --- | --- |
| 604 | 2.15.2 | **Sidewalk Along US-26 at Intersections** | 34d | 2026-06-30 | 2026-08-14 |  | 65d | 0d |
| 605 | 2.15.2.1 | Place Construction Signing | 1d | 2026-06-30 | 2026-06-30 | 600FS-10d | 69d | 0d |
| 606 | 2.15.2.2 | Place Erosion Control Measures | 1d | 2026-07-01 | 2026-07-01 | 605 | 69d | 0d |
| 607 | 2.15.2.3 | Construct Temp Pedestrian Accessible Routes | 4d | 2026-07-02 | 2026-07-07 | 606 | 69d | 4d |
| 608 | 2.15.2.4 | Shift Traffic to TPAR | 1d | 2026-07-14 | 2026-07-14 | 607, 600SS+40d | 65d | 0d |
| 609 | 2.15.2.5 | Saw Cut Existing Shoulder & Pavement Removal | 2d | 2026-07-15 | 2026-07-16 | 608 | 65d | 0d |
| 610 | 2.15.2.6 | Earthwork | 2d | 2026-07-17 | 2026-07-20 | 607, 609 | 65d | 0d |
| 611 | 2.15.2.7 | Place Geotextile/ Agg Base | 1d | 2026-07-21 | 2026-07-21 | 610 | 65d | 0d |
| 612 | 2.15.2.8 | Survey and Acceptance | 3d | 2026-07-22 | 2026-07-24 | 611 | 65d | 0d |
| 613 | 2.15.2.9 | Set Forms for Curb | 1d | 2026-07-27 | 2026-07-27 | 612, 594 | 65d | 0d |
| 614 | 2.15.2.10 | Place Curb | 2d | 2026-07-28 | 2026-07-29 | 613 | 65d | 0d |
| 615 | 2.15.2.11 | Cure Curb | 3d | 2026-07-30 | 2026-08-03 | 614 | 65d | 0d |
| 616 | 2.15.2.12 | Paving & Patching | 1d | 2026-08-04 | 2026-08-04 | 615 | 65d | 0d |
| 617 | 2.15.2.13 | Set Back of Walk Form | 1d | 2026-08-03 | 2026-08-03 | 612, 615FS-1d, 599 | 66d | 1d |
| 618 | 2.15.2.14 | Place Sidewalk & Ped Ramp | 5d | 2026-08-05 | 2026-08-11 | 616, 617 | 65d | 0d |
| 619 | 2.15.2.15 | Cure Sidewalk & Ped Ramp | 3d | 2026-08-12 | 2026-08-14 | 618 | 65d |  |
| 620 | 2.15.3 | **Sidewalk Along Sidestreets & Intersections TPAR Area** | 29d | 2026-08-17 | 2026-09-24 | 604 | 65d | 0d |
| 621 | 2.15.3.1 | Place Construction Signing | 1d | 2026-08-17 | 2026-08-17 |  | 65d | 0d |
| 622 | 2.15.3.2 | Construct Another Set of Temp Pedestrian Accessible Routes | 4d | 2026-08-18 | 2026-08-21 | 621 | 65d | 0d |
| 623 | 2.15.3.3 | Shift Traffic to TPAR | 1d | 2026-08-24 | 2026-08-24 | 622, 601 | 65d | 0d |
| 624 | 2.15.3.4 | Saw Cut Existing Shoulder & Pavement Removal | 2d | 2026-08-25 | 2026-08-26 | 623 | 65d | 0d |
| 625 | 2.15.3.5 | Earthwork | 2d | 2026-08-27 | 2026-08-28 | 622, 624 | 65d | 0d |
| 626 | 2.15.3.6 | Place Geotextile/ Agg Base | 1d | 2026-08-31 | 2026-08-31 | 625 | 65d | 0d |
| 627 | 2.15.3.7 | Survey and Acceptance | 3d | 2026-09-01 | 2026-09-03 | 626 | 65d | 0d |
| 628 | 2.15.3.8 | Set Forms for Curb | 1d | 2026-09-04 | 2026-09-04 | 627 | 65d | 0d |
| 629 | 2.15.3.9 | Place Curb | 2d | 2026-09-07 | 2026-09-08 | 628 | 65d | 0d |
| 630 | 2.15.3.10 | Cure Curb | 3d | 2026-09-09 | 2026-09-11 | 629 | 65d | 0d |
| 631 | 2.15.3.11 | Paving & Patching | 1d | 2026-09-14 | 2026-09-14 | 630 | 65d | 0d |
| 632 | 2.15.3.12 | Set Back of Walk Form | 1d | 2026-09-11 | 2026-09-11 | 627, 630FS-1d | 66d | 1d |
| 633 | 2.15.3.13 | Place Sidewalk & Ped Ramp | 5d | 2026-09-15 | 2026-09-21 | 631, 632 | 65d | 0d |
| 634 | 2.15.3.14 | Cure Sidewalk & Ped Ramp | 3d | 2026-09-22 | 2026-09-24 | 633 | 65d |  |

| ID | WBS | Task | Duration | Start | Finish | Predecessors | Total slack | Free slack |
| --- | --- | --- | --- | --- | --- | --- | --- | --- |
| 635 | 2.15.4 | **Sidewalk in Intersection Radii** | 33d | 2026-09-25 | 2026-11-10 | 620 | 65d | 0d |
| 636 | 2.15.4.1 | Place Construction Signing | 1d | 2026-09-25 | 2026-09-25 |  | 65d | 0d |
| 637 | 2.15.4.2 | Construct Another Set of Temp Pedestrian Accessible Routes | 3d | 2026-09-28 | 2026-09-30 | 636 | 65d | 0d |
| 638 | 2.15.4.3 | Shift Traffic to TPAR | 1d | 2026-10-01 | 2026-10-01 | 637 | 65d | 0d |
| 639 | 2.15.4.4 | Saw Cut Existing Shoulder & Pavement Removal | 2d | 2026-10-02 | 2026-10-05 | 638 | 65d | 0d |
| 640 | 2.15.4.5 | Earthwork | 2d | 2026-10-06 | 2026-10-07 | 637, 639 | 65d | 0d |
| 641 | 2.15.4.6 | Place Geotextile/ Agg Base | 1d | 2026-10-08 | 2026-10-08 | 640 | 65d | 0d |
| 642 | 2.15.4.7 | Survey and Acceptance | 3d | 2026-10-09 | 2026-10-13 | 641 | 65d | 0d |
| 643 | 2.15.4.8 | Set Forms for Curb | 1d | 2026-10-14 | 2026-10-14 | 642 | 65d | 0d |
| 644 | 2.15.4.9 | Place Curb | 2d | 2026-10-15 | 2026-10-16 | 643 | 65d | 0d |
| 645 | 2.15.4.10 | Cure Curb | 3d | 2026-10-19 | 2026-10-21 | 644 | 65d | 0d |
| 646 | 2.15.4.11 | Paving & Patching | 1d | 2026-10-22 | 2026-10-22 | 645 | 65d | 0d |
| 647 | 2.15.4.12 | Set Back of Walk Form | 1d | 2026-10-21 | 2026-10-21 | 642, 645FS-1d | 66d | 1d |
| 648 | 2.15.4.13 | Place Sidewalk & Ped Ramp | 5d | 2026-10-23 | 2026-10-29 | 646, 647 | 65d | 0d |
| 649 | 2.15.4.14 | Cure Sidewalk & Ped Ramp | 3d | 2026-10-30 | 2026-11-03 | 648 | 65d | 0d |
| 650 | 2.15.4.15 | Remove TPARs | 2d | 2026-11-04 | 2026-11-05 | 649 | 68d |  |
| 651 | 2.15.4.16 | Site Paving | 5d | 2026-11-04 | 2026-11-10 | 649 | 65d |  |
| 652 | 2.15.5 | 2026 Project Contingency Days (weather) | 15d | 2026-11-11 | 2026-12-01 | 635 | 65d |  |
| 653 | 2.16 | **SE 148th - ECL STAGE 4: FINAL PAVING** | 48d | 2026-07-27 | 2026-09-30 |  | 161d |  |
| 654 | 2.16.1 | **Phase 1 - Remaining South Side Curb & Raised Bike Lane** | 11d | 2026-07-27 | 2026-08-10 | 511 | 161d |  |
| 655 | 2.16.1.1 | Place Curb | 3d | 2026-07-27 | 2026-07-29 |  | 161d | 0d |
| 656 | 2.16.1.2 | Cure Curb | 3d | 2026-07-30 | 2026-08-03 | 655 | 161d | 0d |
| 657 | 2.16.1.3 | Place Sidewalk (Raised Bike Lane) | 2d | 2026-08-04 | 2026-08-05 | 656 | 161d | 0d |
| 658 | 2.16.1.4 | Cure Sidewalk (Raised Bike Lane) | 3d | 2026-08-06 | 2026-08-10 | 657 | 161d | 0d |

| ID | WBS | Task | Duration | Start | Finish | Predecessors | Total slack | Free slack |
| --- | --- | --- | --- | --- | --- | --- | --- | --- |
| 659 | 2.16.2 | **Phase 2: Complete South Side & Bike Lane Protection Curb** | 18d | 2026-08-11 | 2026-09-03 |  | 161d |  |
| 660 | 2.16.2.1 | **South Side Wearing Course** | 18d | 2026-08-11 | 2026-09-03 |  | 161d | 0d |
| 661 | 2.16.2.1.1 | Place Construction Signing | 1d | 2026-08-11 | 2026-08-11 | 658 | 161d | 0d |
| 662 | 2.16.2.1.2 | Remove/ Cover Existing Striping, Install Temporary Striping | 1d | 2026-08-12 | 2026-08-12 | 661 | 161d | 0d |
| 663 | 2.16.2.1.3 | Planing | 2d | 2026-08-13 | 2026-08-14 | 662 | 161d | 0d |
| 664 | 2.16.2.1.4 | Place ACP Incl Wearing Course | 3d | 2026-08-17 | 2026-08-19 | 663 | 161d | 0d |
| 665 | 2.16.2.1.5 | Adjust Water Valves and Gas Valves | 2d | 2026-08-19 | 2026-08-20 | 664FF+1d | 161d | 0d |
| 666 | 2.16.2.1.6 | Adjust Sanitary Manholes | 1d | 2026-08-21 | 2026-08-21 | 665 | 161d | 0d |
| 667 | 2.16.2.1.7 | Place North Side Bike Lane Protection Curb | 3d | 2026-08-24 | 2026-08-26 | 666 | 161d | 0d |
| 668 | 2.16.2.1.8 | Cure Curb | 3d | 2026-08-27 | 2026-08-31 | 667 | 161d | 0d |
| 669 | 2.16.2.1.9 | Complete Permanent Signing | 3d | 2026-09-01 | 2026-09-03 | 668 | 161d |  |
| 670 | 2.16.3 | **Phase 3: Complete North Side** | 9d | 2026-09-04 | 2026-09-16 |  | 161d |  |
| 671 | 2.16.3.1 | **North Side Wearing Course & Final Markings** | 9d | 2026-09-04 | 2026-09-16 | 660 | 161d | 0d |
| 672 | 2.16.3.1.1 | Install Traffic Control Devices | 1d | 2026-09-04 | 2026-09-04 |  | 161d | 0d |
| 673 | 2.16.3.1.2 | Planing | 2d | 2026-09-07 | 2026-09-08 | 672 | 161d | 0d |
| 674 | 2.16.3.1.3 | Place ACP incl wearing course | 3d | 2026-09-09 | 2026-09-11 | 673 | 161d | 0d |
| 675 | 2.16.3.1.4 | Adjust Water Valves and Gas Valves | 2d | 2026-09-14 | 2026-09-15 | 674 | 161d | 0d |
| 676 | 2.16.3.1.5 | Adjust Sanitary Manholes | 1d | 2026-09-16 | 2026-09-16 | 675 | 161d |  |
| 677 | 2.16.3.1.6 | Permanent Pavement Marking | 3d | 2026-09-14 | 2026-09-16 | 674 | 161d |  |
| 678 | 2.16.4 | 2026 Project Contingency Days (weather) | 10d | 2026-09-17 | 2026-09-30 | 671 | 161d |  |
| 679 | 2.17 | **SE 99th - SE 122nd & SE 136th - SE 148th STAGE 4: FINAL PAVING** | 88d | 2027-01-12 | 2027-05-13 |  | 0d |  |
| 680 | 2.17.1 | **Phase 1 - Remaining South Side Curb & Raised Bike Lane** | 11d | 2027-01-12 | 2027-01-26 | 581, 582 | 36d |  |
| 681 | 2.17.1.1 | Place Curb | 3d | 2027-01-12 | 2027-01-14 | 30 | 36d | 0d |
| 682 | 2.17.1.2 | Cure Curb | 3d | 2027-01-15 | 2027-01-19 | 681 | 36d | 0d |
| 683 | 2.17.1.3 | Place Sidewalk (Raised Bike Lane) | 2d | 2027-01-20 | 2027-01-21 | 682 | 36d | 0d |
| 684 | 2.17.1.4 | Cure Sidewalk (Raised Bike Lane) | 3d | 2027-01-22 | 2027-01-26 | 683 | 36d |  |

| ID | WBS | Task | Duration | Start | Finish | Predecessors | Total slack | Free slack |
| --- | --- | --- | --- | --- | --- | --- | --- | --- |
| 685 | 2.17.2 | **Phase 2: Complete South Side & Bike Lane Protection Curb** | 25d | 2027-03-16 | 2027-04-19 | 582, 511 | 0d |  |
| 686 | 2.17.2.1 | **South Side Wearing Course** | 25d | 2027-03-16 | 2027-04-19 | 26 | 0d |  |
| 687 | 2.17.2.1.1 | Place Construction Signing | 1d | 2027-03-16 | 2027-03-16 |  | 0d |  |
| 688 | 2.17.2.1.2 | Remove/ Cover Existing Striping, Install Temporary Striping | 1d | 2027-03-17 | 2027-03-17 | 687 | 0d |  |
| 689 | 2.17.2.1.3 | Planing | 2d | 2027-03-18 | 2027-03-19 | 688, 684 | 0d |  |
| 690 | 2.17.2.1.4 | Place ACP Incl Wearing Course | 7d | 2027-03-22 | 2027-03-30 | 689 | 0d |  |
| 691 | 2.17.2.1.5 | Adjust Water Valves and Gas Valves | 3d | 2027-03-29 | 2027-03-31 | 690FF+1d | 0d |  |
| 692 | 2.17.2.1.6 | Adjust Sanitary Manholes | 1d | 2027-04-01 | 2027-04-01 | 691 | 0d |  |
| 693 | 2.17.2.1.7 | Place North Side Bike Lane Protection Curb | 6d | 2027-04-02 | 2027-04-09 | 692 | 0d |  |
| 694 | 2.17.2.1.8 | Cure Curb | 3d | 2027-04-12 | 2027-04-14 | 693 | 0d |  |
| 695 | 2.17.2.1.9 | Complete Permanent Signing | 3d | 2027-04-15 | 2027-04-19 | 690, 694 | 0d |  |
| 696 | 2.17.3 | **Phase 3: Complete North Side** | 16d | 2027-04-20 | 2027-05-11 | 686 | 0d |  |
| 697 | 2.17.3.1 | **North Side Wearing Course & Final Markings** | 16d | 2027-04-20 | 2027-05-11 |  | 0d |  |
| 698 | 2.17.3.1.1 | Install Traffic Control Devices | 1d | 2027-04-20 | 2027-04-20 |  | 0d |  |
| 699 | 2.17.3.1.2 | Planing | 2d | 2027-04-21 | 2027-04-22 | 698 | 0d |  |
| 700 | 2.17.3.1.3 | Place ACP incl wearing course | 7d | 2027-04-23 | 2027-05-03 | 699 | 0d |  |
| 701 | 2.17.3.1.4 | Adjust Water Valves and Gas Valves | 3d | 2027-05-04 | 2027-05-06 | 700 | 2d | 0d |
| 702 | 2.17.3.1.5 | Adjust Sanitary Manholes | 1d | 2027-05-07 | 2027-05-07 | 701 | 2d |  |
| 703 | 2.17.3.1.6 | Permanent Pavement Marking | 6d | 2027-05-04 | 2027-05-11 | 700 | 0d |  |
| 704 | 2.17.4 | 2027 Project Contingency Days (weather) | 2d | 2027-05-12 | 2027-05-13 | 697 | 0d |  |
| 705 | 2.18 | Complete Disposal Site Grading and Seed | 15d | 2026-11-11 | 2026-12-01 | 635 | 117d |  |
| 706 | 2.19 | Demobilization and Cleanup | 2d | 2027-05-12 | 2027-05-13 | 696 | 0d |  |
